# 8-Kings1

Schedule from MS Project, 2003-06-23 to 2003-10-24.

## Calendars

- Standard: Mon-Fri 08:00-12:00, 13:00-17:00; Sat-Sun off.

## Resources

| Resource | Group |
| --- | --- |
| Martin piper | Code |
| Will Hanson | Code |
| Stuart Scott | Art |
| Oscar Ferrero | Art |
| Steven Taylor | Design |
| Craig Howard | Project lead |
| Douglas hickmore | Art |
| Musician | Music |
| Lead Test (Dominic) | Test |
| Tester | Test |
| Publisher |  |
| Script Writer |  |

## Schedule

| ID | WBS | Task | Type | Duration | Start | Finish | Predecessors | Total slack | Free slack | Resources | Work |
| --- | --- | --- | --- | --- | --- | --- | --- | --- | --- | --- | --- |
| 2 | 1 | **8 Kings project schedule** |  | 90d? | 2003-06-23 08:00 | 2003-10-24 17:00 |  | 0d |  |  | 3980h |
| 3 | 1.1 | **Milestones** |  | 55d | 2003-08-08 17:00 | 2003-10-24 17:00 |  | 0d |  |  |  |
| 4 | 1.1.1 | ALPHA | milestone | 0d | 2003-08-08 17:00 | 2003-08-08 17:00 | 9 | 46d | 35d |  |  |
| 5 | 1.1.2 | BETA | milestone | 0d | 2003-09-26 17:00 | 2003-09-26 17:00 | 276, 4 | 11d | 10d |  |  |
| 6 | 1.1.3 | FULL SUBMISSION CANDIDATE | milestone | 0d | 2003-10-10 17:00 | 2003-10-10 17:00 | 544, 5 | 1d |  |  |  |
| 7 | 1.1.4 | GOLD MASTER CANDIDATE | milestone | 0d | 2003-10-24 17:00 | 2003-10-24 17:00 | 6, 552 | 0d |  |  |  |
| 9 | 1.2 | **ALPHA** |  | 35d | 2003-06-23 08:00 | 2003-08-08 17:00 |  | 0d |  |  | 1696h |
| 10 | 1.2.1 | **CODE** |  | 35d | 2003-06-23 08:00 | 2003-08-08 17:00 |  | 0d |  |  | 544h |
| 11 | 1.2.1.1 | **Cursor modifications** |  | 3d | 2003-06-23 08:00 | 2003-06-25 17:00 |  | 0d |  |  | 24h |
| 12 | 1.2.1.1.1 | Cursor needs to 'stick' at the extent of unit movement |  | 0.5d | 2003-06-23 08:00 | 2003-06-23 12:00 |  | 0d |  | Will Hanson | 4h |
| 13 | 1.2.1.1.2 | player should be able to change cursor direction instantly |  | 0.5d | 2003-06-23 13:00 | 2003-06-23 17:00 | 12 | 0d |  | Will Hanson | 4h |
| 14 | 1.2.1.1.3 | show the buildings accrue money |  | 0.5d | 2003-06-24 08:00 | 2003-06-24 12:00 | 13 | 0d |  | Will Hanson | 4h |
| 15 | 1.2.1.1.4 | The cursor should never move off-screen |  | 0.5d | 2003-06-24 13:00 | 2003-06-24 17:00 | 14 | 0d |  | Will Hanson | 4h |
| 16 | 1.2.1.1.5 | rapidly tap in one direction the cursor does not respond in a predictable manner |  | 0.5d | 2003-06-25 08:00 | 2003-06-25 12:00 | 15 | 0d |  | Will Hanson | 4h |
| 17 | 1.2.1.1.6 | Diagonal movement |  | 0.5d | 2003-06-25 13:00 | 2003-06-25 17:00 | 16 | 0d |  | Will Hanson | 4h |
| 18 | 1.2.1.2 | **Battle map** |  | 1d | 2003-06-26 08:00 | 2003-06-26 17:00 | 11 | 0d |  |  | 8h |
| 19 | 1.2.1.2.1 | Animated Unit graphics (battle map) |  | 0.5d | 2003-06-26 08:00 | 2003-06-26 12:00 |  | 0d |  | Will Hanson | 4h |
| 20 | 1.2.1.2.2 | Dim moved Units |  | 0.5d | 2003-06-26 13:00 | 2003-06-26 17:00 | 19 | 0d |  | Will Hanson | 4h |
| 21 | 1.2.1.3 | **Map Editor / Tool chain work** |  | 8d | 2003-06-23 08:00 | 2003-07-02 17:00 |  | 2d | 0d |  | 64h |
| 22 | 1.2.1.3.1 | refine tool chain and map editor (Add list) |  | 8d | 2003-06-23 08:00 | 2003-07-02 17:00 |  | 2d |  | Martin piper | 64h |
| 23 | 1.2.1.4 | **Resource Management Screens** |  | 9d | 2003-06-27 08:00 | 2003-07-09 17:00 | 18 | 0d |  |  | 72h |
| 24 | 1.2.1.4.1 | Casino resource management |  | 2d | 2003-06-27 08:00 | 2003-06-30 17:00 |  | 0d |  | Will Hanson | 16h |
| 25 | 1.2.1.4.2 | Bank Resource screen |  | 2d | 2003-07-01 08:00 | 2003-07-02 17:00 | 24 | 0d |  | Will Hanson | 16h |
| 26 | 1.2.1.4.3 | jail Resource screen |  | 2d | 2003-07-03 08:00 | 2003-07-04 17:00 | 25 | 0d |  | Will Hanson | 16h |
| 27 | 1.2.1.4.4 | Strip Bar club resource management |  | 1d | 2003-07-07 08:00 | 2003-07-07 17:00 | 26 | 0d |  | Will Hanson | 8h |
| 28 | 1.2.1.4.5 | Final resource management balancing |  | 2d | 2003-07-08 08:00 | 2003-07-09 17:00 | 27 | 0d |  | Will Hanson | 16h |

Notes:
- 9: Alpha. This version of the game will have all assets included in the game. They may not be of final quality however their functionality must be implemented. There will be bugs, final pass art refinements and changes still made to the game AI. However the Alpha submission will give a glimpse towards the final pass of the game.

| ID | WBS | Task | Duration | Start | Finish | Predecessors | Total slack | Free slack | Resources | Work |
| --- | --- | --- | --- | --- | --- | --- | --- | --- | --- | --- |
| 29 | 1.2.1.5 | **Additional transport methods** | 5d | 2003-07-10 08:00 | 2003-07-16 17:00 | 23 | 0d |  |  | 40h |
| 30 | 1.2.1.5.1 | Train | 2d | 2003-07-10 08:00 | 2003-07-11 17:00 |  | 0d |  | Will Hanson | 16h |
| 31 | 1.2.1.5.2 | Sea-ports | 2d | 2003-07-14 08:00 | 2003-07-15 17:00 | 30 | 0d |  | Will Hanson | 16h |
| 32 | 1.2.1.5.3 | Airports | 1d | 2003-07-16 08:00 | 2003-07-16 17:00 | 31 | 0d |  | Will Hanson | 8h |
| 33 | 1.2.1.6 | **Strategy map** | 2d | 2003-08-04 08:00 | 2003-08-05 17:00 | 48 | 2d | 0d |  | 16h |
| 34 | 1.2.1.6.1 | Code functionality of an overall map zoom | 2d | 2003-08-04 08:00 | 2003-08-05 17:00 |  | 2d |  | Martin piper | 16h |
| 35 | 1.2.1.7 | **Localisation Dialogue System** | 5d | 2003-07-16 08:00 | 2003-07-22 17:00 | 72 | 2d | 0d |  | 40h |
| 36 | 1.2.1.7.1 | Set up text strings | 2d | 2003-07-16 08:00 | 2003-07-17 17:00 |  | 2d | 0d | Martin piper | 16h |
| 37 | 1.2.1.7.2 | Set up translation support | 3d | 2003-07-18 08:00 | 2003-07-22 17:00 | 36 | 2d |  | Martin piper | 24h |
| 38 | 1.2.1.8 | **HOTSEAT** | 1d | 2003-07-17 08:00 | 2003-07-17 17:00 | 29 | 0d |  |  | 8h |
| 39 | 1.2.1.8.1 | Hotseat Functionality (tweaks) | 1d | 2003-07-17 08:00 | 2003-07-17 17:00 |  | 0d |  | Will Hanson | 8h |
| 40 | 1.2.1.9 | **UI implementation** | 3d | 2003-07-23 08:00 | 2003-07-25 17:00 | 35 | 2d | 0d |  | 24h |
| 41 | 1.2.1.9.1 | Get text box / Dialogue system refined | 2d | 2003-07-23 08:00 | 2003-07-24 17:00 |  | 2d | 0d | Martin piper | 16h |
| 42 | 1.2.1.9.2 | Include Temperament Indicator (for angry / happy face to be displayed on the panel) | 1d | 2003-07-25 08:00 | 2003-07-25 17:00 | 41 | 2d |  | Martin piper | 8h |
| 43 | 1.2.1.10 | **Screen fades** | 2d | 2003-07-28 08:00 | 2003-07-29 17:00 | 40 | 2d | 0d |  | 16h |
| 44 | 1.2.1.10.1 | Screen fade quick to black | 0.5d | 2003-07-28 08:00 | 2003-07-28 12:00 |  | 2d | 0d | Martin piper | 4h |
| 45 | 1.2.1.10.2 | Screen fade quick to white | 0.5d | 2003-07-28 13:00 | 2003-07-28 17:00 | 44 | 2d | 0d | Martin piper | 4h |
| 46 | 1.2.1.10.3 | Screen fade slow (to black) | 0.5d | 2003-07-29 08:00 | 2003-07-29 12:00 | 45 | 2d | 0d | Martin piper | 4h |
| 47 | 1.2.1.10.4 | Screen fade slow (to white) | 0.5d | 2003-07-29 13:00 | 2003-07-29 17:00 | 46 | 2d |  | Martin piper | 4h |
| 48 | 1.2.1.11 | **Screen Wipes** | 3d | 2003-07-30 08:00 | 2003-08-01 17:00 | 43 | 2d | 0d |  | 24h |
| 49 | 1.2.1.11.1 | Slice screen effect | 1d | 2003-07-30 08:00 | 2003-07-30 17:00 |  | 2d | 0d | Martin piper | 8h |
| 50 | 1.2.1.11.2 | Block screen effect | 1d | 2003-07-31 08:00 | 2003-07-31 17:00 | 49 | 2d | 0d | Martin piper | 8h |
| 51 | 1.2.1.11.3 | research filter effect? | 1d | 2003-08-01 08:00 | 2003-08-01 17:00 | 50 | 2d |  | Martin piper | 8h |
| 52 | 1.2.1.12 | **Campaign Map** | 6d | 2003-07-18 08:00 | 2003-07-25 17:00 | 38 | 0d |  |  | 48h |
| 53 | 1.2.1.12.1 | Get flashing sectors working | 1d | 2003-07-18 08:00 | 2003-07-18 17:00 |  | 0d |  | Will Hanson | 8h |
| 54 | 1.2.1.12.2 | Scripting design & implementation | 3d | 2003-07-21 08:00 | 2003-07-23 17:00 | 53 | 0d |  | Will Hanson | 24h |
| 55 | 1.2.1.12.3 | Get selection arrows working | 1d | 2003-07-24 08:00 | 2003-07-24 17:00 | 54 | 0d |  | Will Hanson | 8h |
| 56 | 1.2.1.12.4 | get Enemy taunts working | 1d | 2003-07-25 08:00 | 2003-07-25 17:00 | 55 | 0d |  | Will Hanson | 8h |

| ID | WBS | Task | Duration | Start | Finish | Predecessors | Total slack | Free slack | Resources | Work |
| --- | --- | --- | --- | --- | --- | --- | --- | --- | --- | --- |
| 57 | 1.2.1.13 | **Office** | 5d | 2003-08-04 08:00 | 2003-08-08 17:00 | 79 | 0d |  |  | 40h |
| 58 | 1.2.1.13.1 | **Statistics Screen** | 2d | 2003-08-04 08:00 | 2003-08-05 17:00 |  | 0d |  |  | 16h |
| 59 | 1.2.1.13.1.1 | Statistics Functionality | 1d | 2003-08-04 08:00 | 2003-08-04 17:00 |  | 0d |  | Will Hanson | 8h |
| 60 | 1.2.1.13.1.2 | Menu GFX | 1d | 2003-08-05 08:00 | 2003-08-05 17:00 | 59 | 0d |  | Will Hanson | 8h |
| 61 | 1.2.1.13.2 | **Telephone screen** | 1.5d | 2003-08-06 08:00 | 2003-08-07 12:00 | 58 | 0d |  |  | 12h |
| 62 | 1.2.1.13.2.1 | Menu screen | 0.5d | 2003-08-06 08:00 | 2003-08-06 12:00 |  | 0d |  | Will Hanson | 4h |
| 63 | 1.2.1.13.2.2 | Spy functionality | 1d | 2003-08-06 13:00 | 2003-08-07 12:00 | 62 | 0d |  | Will Hanson | 8h |
| 64 | 1.2.1.13.3 | **Office Options Screen** | 1.5d | 2003-08-07 13:00 | 2003-08-08 17:00 | 61 | 0d |  |  | 12h |
| 65 | 1.2.1.13.3.1 | menu screen code | 1d | 2003-08-07 13:00 | 2003-08-08 12:00 |  | 0d |  | Will Hanson | 8h |
| 66 | 1.2.1.13.3.2 | check functionality works | 0.5d | 2003-08-08 13:00 | 2003-08-08 17:00 | 65 | 0d |  | Will Hanson | 4h |
| 67 | 1.2.1.14 | **Attract Mode** | 1d | 2003-08-06 08:00 | 2003-08-06 17:00 | 33 | 2d |  |  | 8h |
| 68 | 1.2.1.14.1 | Attract mode (game attract mode Coding) | 1d | 2003-08-06 08:00 | 2003-08-06 17:00 |  | 2d |  | Martin piper | 8h |
| 69 | 1.2.1.15 | **Game over** | 1d | 2003-07-28 08:00 | 2003-07-28 17:00 | 52 | 0d |  |  | 8h |
| 70 | 1.2.1.15.1 | Game over winning screen Code | 0.5d | 2003-07-28 08:00 | 2003-07-28 12:00 |  | 0d |  | Will Hanson | 4h |
| 71 | 1.2.1.15.2 | Game over losing screen code | 0.5d | 2003-07-28 13:00 | 2003-07-28 17:00 | 70 | 0d |  | Will Hanson | 4h |
| 72 | 1.2.1.16 | **Office Battlemap** | 9d | 2003-07-03 08:00 | 2003-07-15 17:00 | 21 | 2d | 0d |  | 72h |
| 73 | 1.2.1.16.1 | Unit selection | 2d | 2003-07-03 08:00 | 2003-07-04 17:00 |  | 2d | 0d | Martin piper | 16h |
| 74 | 1.2.1.16.2 | Cut scene set-ups | 3d | 2003-07-07 08:00 | 2003-07-09 17:00 | 73 | 2d | 0d | Martin piper | 24h |
| 75 | 1.2.1.16.3 | Integration of sharpshooter in the office section (no battle scenes). | 1d | 2003-07-10 08:00 | 2003-07-10 17:00 | 74 | 2d | 0d | Martin piper | 8h |
| 76 | 1.2.1.16.4 | Integration of super-trackpiece support | 1d | 2003-07-11 08:00 | 2003-07-11 17:00 | 75 | 2d | 0d | Martin piper | 8h |
| 77 | 1.2.1.16.5 | Hooks to allow office battle functionalty to link from the game map | 1d | 2003-07-14 08:00 | 2003-07-14 17:00 | 76 | 2d | 0d | Martin piper | 8h |
| 78 | 1.2.1.16.6 | animated unit support for battle map | 1d | 2003-07-15 08:00 | 2003-07-15 17:00 | 77 | 2d |  | Martin piper | 8h |
| 79 | 1.2.1.17 | **Newspaper reports** | 4d | 2003-07-29 08:00 | 2003-08-01 17:00 | 69 | 0d |  |  | 32h |
| 80 | 1.2.1.17.1 | Get newspaper system working fully | 4d | 2003-07-29 08:00 | 2003-08-01 17:00 |  | 0d |  | Will Hanson | 32h |

| ID | WBS | Task | Duration | Start | Finish | Predecessors | Total slack | Resources | Work |
| --- | --- | --- | --- | --- | --- | --- | --- | --- | --- |
| 81 | 1.2.2 | **ART** | 35d | 2003-06-23 08:00 | 2003-08-08 17:00 |  | 0d |  | 808h |
| 82 | 1.2.2.1 | Finalise art style | 10d | 2003-06-23 08:00 | 2003-07-04 17:00 |  | 0d | Stuart Scott; Oscar Ferrero; Douglas hickmore | 240h |
| 83 | 1.2.2.2 | **Newspaper Graphics** | 6d | 2003-08-01 08:00 | 2003-08-08 17:00 | 87 | 0d |  | 48h |
| 84 | 1.2.2.2.1 | Basic newspaper Template | 1d | 2003-08-01 08:00 | 2003-08-01 17:00 |  | 0d | Stuart Scott | 8h |
| 85 | 1.2.2.2.2 | Newspaper font | 1d | 2003-08-04 08:00 | 2003-08-04 17:00 | 84 | 0d | Stuart Scott | 8h |
| 86 | 1.2.2.2.3 | Newspaper Pics | 4d | 2003-08-05 08:00 | 2003-08-08 17:00 | 85 | 0d | Stuart Scott | 32h |
| 87 | 1.2.2.3 | **Battle cut scenes for individual units** | 19d | 2003-07-07 08:00 | 2003-07-31 17:00 | 82 | 0d |  | 152h |
| 88 | 1.2.2.3.1 | Soldier | 1d | 2003-07-07 08:00 | 2003-07-07 17:00 |  | 0d | Stuart Scott | 8h |
| 89 | 1.2.2.3.2 | Captain | 1d | 2003-07-08 08:00 | 2003-07-08 17:00 | 88 | 0d | Stuart Scott | 8h |
| 90 | 1.2.2.3.3 | Sniper | 1d | 2003-07-09 08:00 | 2003-07-09 17:00 | 89 | 0d | Stuart Scott | 8h |
| 91 | 1.2.2.3.4 | motorbike | 1d | 2003-07-10 08:00 | 2003-07-10 17:00 | 90 | 0d | Stuart Scott | 8h |
| 92 | 1.2.2.3.5 | Car | 1d | 2003-07-11 08:00 | 2003-07-11 17:00 | 91 | 0d | Stuart Scott | 8h |
| 93 | 1.2.2.3.6 | Heavy Car | 1d | 2003-07-14 08:00 | 2003-07-14 17:00 | 92 | 0d | Stuart Scott | 8h |
| 94 | 1.2.2.3.7 | Boss car | 1d | 2003-07-15 08:00 | 2003-07-15 17:00 | 93 | 0d | Stuart Scott | 8h |
| 95 | 1.2.2.3.8 | Gun truck | 1d | 2003-07-16 08:00 | 2003-07-16 17:00 | 94 | 0d | Stuart Scott | 8h |
| 96 | 1.2.2.3.9 | Van | 1d | 2003-07-17 08:00 | 2003-07-17 17:00 | 95 | 0d | Stuart Scott | 8h |
| 97 | 1.2.2.3.10 | Lorry | 1d | 2003-07-18 08:00 | 2003-07-18 17:00 | 96 | 0d | Stuart Scott | 8h |
| 98 | 1.2.2.3.11 | speedboat | 1d | 2003-07-21 08:00 | 2003-07-21 17:00 | 97 | 0d | Stuart Scott | 8h |
| 99 | 1.2.2.3.12 | Cruiser | 1d | 2003-07-22 08:00 | 2003-07-22 17:00 | 98 | 0d | Stuart Scott | 8h |
| 100 | 1.2.2.3.13 | Submarine | 1d | 2003-07-23 08:00 | 2003-07-23 17:00 | 99 | 0d | Stuart Scott | 8h |
| 101 | 1.2.2.3.14 | Barge | 1d | 2003-07-24 08:00 | 2003-07-24 17:00 | 100 | 0d | Stuart Scott | 8h |
| 102 | 1.2.2.3.15 | Bi-Plane | 1d | 2003-07-25 08:00 | 2003-07-25 17:00 | 101 | 0d | Stuart Scott | 8h |
| 103 | 1.2.2.3.16 | Fighter | 1d | 2003-07-28 08:00 | 2003-07-28 17:00 | 102 | 0d | Stuart Scott | 8h |
| 104 | 1.2.2.3.17 | AA Gun | 1d | 2003-07-29 08:00 | 2003-07-29 17:00 | 103 | 0d | Stuart Scott | 8h |
| 105 | 1.2.2.3.18 | Train | 1d | 2003-07-30 08:00 | 2003-07-30 17:00 | 104 | 0d | Stuart Scott | 8h |
| 106 | 1.2.2.3.19 | Airship | 1d | 2003-07-31 08:00 | 2003-07-31 17:00 | 105 | 0d | Stuart Scott | 8h |

| ID | WBS | Task | Duration | Start | Finish | Predecessors | Total slack | Resources | Work |
| --- | --- | --- | --- | --- | --- | --- | --- | --- | --- |
| 107 | 1.2.2.4 | **Battle map units** | 10d | 2003-07-07 08:00 | 2003-07-18 17:00 | 82 | 0d |  | 80h |
| 108 | 1.2.2.4.1 | Soldier | 0.5d | 2003-07-07 08:00 | 2003-07-07 12:00 |  | 0d | Douglas hickmore | 4h |
| 109 | 1.2.2.4.2 | Captain | 0.5d | 2003-07-07 13:00 | 2003-07-07 17:00 | 108 | 0d | Douglas hickmore | 4h |
| 110 | 1.2.2.4.3 | Sniper | 0.5d | 2003-07-08 08:00 | 2003-07-08 12:00 | 109 | 0d | Douglas hickmore | 4h |
| 111 | 1.2.2.4.4 | motorbike | 0.5d | 2003-07-08 13:00 | 2003-07-08 17:00 | 110 | 0d | Douglas hickmore | 4h |
| 112 | 1.2.2.4.5 | Car | 0.5d | 2003-07-09 08:00 | 2003-07-09 12:00 | 111 | 0d | Douglas hickmore | 4h |
| 113 | 1.2.2.4.6 | Heavy Car | 0.5d | 2003-07-09 13:00 | 2003-07-09 17:00 | 112 | 0d | Douglas hickmore | 4h |
| 114 | 1.2.2.4.7 | Boss car | 0.5d | 2003-07-10 08:00 | 2003-07-10 12:00 | 113 | 0d | Douglas hickmore | 4h |
| 115 | 1.2.2.4.8 | Gun truck | 0.5d | 2003-07-10 13:00 | 2003-07-10 17:00 | 114 | 0d | Douglas hickmore | 4h |
| 116 | 1.2.2.4.9 | Van | 0.5d | 2003-07-11 08:00 | 2003-07-11 12:00 | 115 | 0d | Douglas hickmore | 4h |
| 117 | 1.2.2.4.10 | Lorry | 0.5d | 2003-07-11 13:00 | 2003-07-11 17:00 | 116 | 0d | Douglas hickmore | 4h |
| 118 | 1.2.2.4.11 | speedboat | 0.5d | 2003-07-14 08:00 | 2003-07-14 12:00 | 117 | 0d | Douglas hickmore | 4h |
| 119 | 1.2.2.4.12 | Cruiser | 0.5d | 2003-07-14 13:00 | 2003-07-14 17:00 | 118 | 0d | Douglas hickmore | 4h |
| 120 | 1.2.2.4.13 | Submarine | 0.5d | 2003-07-15 08:00 | 2003-07-15 12:00 | 119 | 0d | Douglas hickmore | 4h |
| 121 | 1.2.2.4.14 | Barge | 0.5d | 2003-07-15 13:00 | 2003-07-15 17:00 | 120 | 0d | Douglas hickmore | 4h |
| 122 | 1.2.2.4.15 | Bi-Plane | 0.5d | 2003-07-16 08:00 | 2003-07-16 12:00 | 121 | 0d | Douglas hickmore | 4h |
| 123 | 1.2.2.4.16 | Fighter | 0.5d | 2003-07-16 13:00 | 2003-07-16 17:00 | 122 | 0d | Douglas hickmore | 4h |
| 124 | 1.2.2.4.17 | AA Gun | 0.5d | 2003-07-17 08:00 | 2003-07-17 12:00 | 123 | 0d | Douglas hickmore | 4h |
| 125 | 1.2.2.4.18 | Train | 0.5d | 2003-07-17 13:00 | 2003-07-17 17:00 | 124 | 0d | Douglas hickmore | 4h |
| 126 | 1.2.2.4.19 | Airship | 0.5d | 2003-07-18 08:00 | 2003-07-18 12:00 | 125 | 0d | Douglas hickmore | 4h |
| 127 | 1.2.2.4.20 | Bomb Truck | 0.5d | 2003-07-18 13:00 | 2003-07-18 17:00 | 126 | 0d | Douglas hickmore | 4h |
| 128 | 1.2.2.5 | **Incidental Sprites** | 5d | 2003-07-21 08:00 | 2003-07-25 17:00 | 107 | 0d |  | 40h |
| 129 | 1.2.2.5.1 | Explosions | 2d | 2003-07-21 08:00 | 2003-07-22 17:00 |  | 0d | Douglas hickmore | 16h |
| 130 | 1.2.2.5.2 | Gun effects | 2d | 2003-07-23 08:00 | 2003-07-24 17:00 | 129 | 0d | Douglas hickmore | 16h |
| 131 | 1.2.2.5.3 | other | 1d | 2003-07-25 08:00 | 2003-07-25 17:00 | 130 | 0d | Douglas hickmore | 8h |

| ID | WBS | Task | Duration | Start | Finish | Predecessors | Total slack | Free slack | Resources | Work |
| --- | --- | --- | --- | --- | --- | --- | --- | --- | --- | --- |
| 132 | 1.2.2.6 | **SPY** | 3d | 2003-08-06 08:00 | 2003-08-08 17:00 | 135 | 0d |  |  | 24h |
| 133 | 1.2.2.6.1 | Spy Character GFX for Dialogue Box | 1d | 2003-08-06 08:00 | 2003-08-06 17:00 |  | 0d |  | Douglas hickmore | 8h |
| 134 | 1.2.2.6.2 | Spy screen | 2d | 2003-08-07 08:00 | 2003-08-08 17:00 | 133 | 0d |  | Douglas hickmore | 16h |
| 135 | 1.2.2.7 | **Resource Gfx** | 7d | 2003-07-28 08:00 | 2003-08-05 17:00 | 128 | 0d |  |  | 56h |
| 136 | 1.2.2.7.1 | Strip bar background | 1d | 2003-07-28 08:00 | 2003-07-28 17:00 |  | 0d |  | Douglas hickmore | 8h |
| 137 | 1.2.2.7.2 | factory backgorund | 1d | 2003-07-29 08:00 | 2003-07-29 17:00 | 136 | 0d |  | Douglas hickmore | 8h |
| 138 | 1.2.2.7.3 | jail back gorund | 1d | 2003-07-30 08:00 | 2003-07-30 17:00 | 137 | 0d |  | Douglas hickmore | 8h |
| 139 | 1.2.2.7.4 | bank background | 1d | 2003-07-31 08:00 | 2003-07-31 17:00 | 138 | 0d |  | Douglas hickmore | 8h |
| 140 | 1.2.2.7.5 | Airport GFX | 1d | 2003-08-01 08:00 | 2003-08-01 17:00 | 139 | 0d |  | Douglas hickmore | 8h |
| 141 | 1.2.2.7.6 | Sea Port GFX | 1d | 2003-08-04 08:00 | 2003-08-04 17:00 | 140 | 0d |  | Douglas hickmore | 8h |
| 142 | 1.2.2.7.7 | Railway GFX | 1d | 2003-08-05 08:00 | 2003-08-05 17:00 | 141 | 0d |  | Douglas hickmore | 8h |
| 143 | 1.2.2.8 | **King models** | 8d | 2003-07-07 08:00 | 2003-07-16 17:00 | 82 | 4d |  |  | 64h |
| 144 | 1.2.2.8.1 | **Donovan Howard** | 1d | 2003-07-07 08:00 | 2003-07-07 17:00 |  | 4d | 0d |  | 8h |
| 145 | 1.2.2.8.1.1 | Final 3d Model | 1d | 2003-07-07 08:00 | 2003-07-07 17:00 |  | 4d |  | Oscar Ferrero | 8h |
| 146 | 1.2.2.8.2 | **Sue Lee** | 1d | 2003-07-08 08:00 | 2003-07-08 17:00 | 144 | 4d | 0d |  | 8h |
| 147 | 1.2.2.8.2.1 | Final 3d Model | 1d | 2003-07-08 08:00 | 2003-07-08 17:00 |  | 4d |  | Oscar Ferrero | 8h |
| 148 | 1.2.2.8.3 | **Lord Excelsior** | 1d | 2003-07-09 08:00 | 2003-07-09 17:00 | 146 | 4d | 0d |  | 8h |
| 149 | 1.2.2.8.3.1 | Final 3d Model | 1d | 2003-07-09 08:00 | 2003-07-09 17:00 |  | 4d |  | Oscar Ferrero | 8h |
| 150 | 1.2.2.8.4 | **Yu Tosumi** | 1d | 2003-07-10 08:00 | 2003-07-10 17:00 | 148 | 4d | 0d |  | 8h |
| 151 | 1.2.2.8.4.1 | Final 3d Model | 1d | 2003-07-10 08:00 | 2003-07-10 17:00 |  | 4d |  | Oscar Ferrero | 8h |
| 152 | 1.2.2.8.5 | **Kurt Rollins** | 1d | 2003-07-11 08:00 | 2003-07-11 17:00 | 150 | 4d | 0d |  | 8h |
| 153 | 1.2.2.8.5.1 | Final 3d Model | 1d | 2003-07-11 08:00 | 2003-07-11 17:00 |  | 4d |  | Oscar Ferrero | 8h |
| 154 | 1.2.2.8.6 | **Hugh Anderson** | 1d | 2003-07-14 08:00 | 2003-07-14 17:00 | 152 | 4d | 0d |  | 8h |
| 155 | 1.2.2.8.6.1 | Final 3d Model | 1d | 2003-07-14 08:00 | 2003-07-14 17:00 |  | 4d |  | Oscar Ferrero | 8h |

| ID | WBS | Task | Duration | Start | Finish | Predecessors | Total slack | Free slack | Resources | Work |
| --- | --- | --- | --- | --- | --- | --- | --- | --- | --- | --- |
| 156 | 1.2.2.8.7 | **Mr. K** | 1d | 2003-07-15 08:00 | 2003-07-15 17:00 | 154 | 4d | 0d |  | 8h |
| 157 | 1.2.2.8.7.1 | Final 3d Model | 1d | 2003-07-15 08:00 | 2003-07-15 17:00 |  | 4d |  | Oscar Ferrero | 8h |
| 158 | 1.2.2.8.8 | **Charles Nathan Smith** | 1d | 2003-07-16 08:00 | 2003-07-16 17:00 | 156 | 4d | 0d |  | 8h |
| 159 | 1.2.2.8.8.1 | Final 3d Model | 1d | 2003-07-16 08:00 | 2003-07-16 17:00 |  | 4d |  | Oscar Ferrero | 8h |
| 160 | 1.2.2.9 | **Cut scene Unit Graphics (refine)** | 13d | 2003-07-17 08:00 | 2003-08-04 17:00 | 158 | 4d |  |  | 104h |
| 161 | 1.2.2.9.1 | Soldier | 1d | 2003-07-17 08:00 | 2003-07-17 17:00 |  | 4d | 0d | Oscar Ferrero | 8h |
| 162 | 1.2.2.9.2 | Captain | 1d | 2003-07-18 08:00 | 2003-07-18 17:00 | 161 | 4d | 0d | Oscar Ferrero | 8h |
| 163 | 1.2.2.9.3 | Sniper | 1d | 2003-07-21 08:00 | 2003-07-21 17:00 | 162 | 4d | 0d | Oscar Ferrero | 8h |
| 164 | 1.2.2.9.4 | motorbike | 1d | 2003-07-22 08:00 | 2003-07-22 17:00 | 163 | 4d | 0d | Oscar Ferrero | 8h |
| 165 | 1.2.2.9.5 | Car | 1d | 2003-07-23 08:00 | 2003-07-23 17:00 | 164 | 4d | 0d | Oscar Ferrero | 8h |
| 166 | 1.2.2.9.6 | Heavy Car | 1d | 2003-07-24 08:00 | 2003-07-24 17:00 | 165 | 4d | 0d | Oscar Ferrero | 8h |
| 167 | 1.2.2.9.7 | Boss car | 1d | 2003-07-25 08:00 | 2003-07-25 17:00 | 166 | 4d | 0d | Oscar Ferrero | 8h |
| 168 | 1.2.2.9.8 | Gun truck | 1d | 2003-07-28 08:00 | 2003-07-28 17:00 | 167 | 4d | 0d | Oscar Ferrero | 8h |
| 169 | 1.2.2.9.9 | Van | 1d | 2003-07-29 08:00 | 2003-07-29 17:00 | 168 | 4d | 0d | Oscar Ferrero | 8h |
| 170 | 1.2.2.9.10 | Lorry | 1d | 2003-07-30 08:00 | 2003-07-30 17:00 | 169 | 4d | 0d | Oscar Ferrero | 8h |
| 171 | 1.2.2.9.11 | speedboat | 1d | 2003-07-31 08:00 | 2003-07-31 17:00 | 170 | 4d | 0d | Oscar Ferrero | 8h |
| 172 | 1.2.2.9.12 | Cruiser | 1d | 2003-08-01 08:00 | 2003-08-01 17:00 | 171 | 4d | 0d | Oscar Ferrero | 8h |
| 173 | 1.2.2.9.13 | Submarine | 1d | 2003-08-04 08:00 | 2003-08-04 17:00 | 172 | 4d |  | Oscar Ferrero | 8h |
| 174 | 1.2.3 | **DESIGN** | 35d | 2003-06-23 08:00 | 2003-08-08 17:00 |  | 0d |  |  | 344h |
| 175 | 1.2.3.1 | **Basic layout of maps** | 35d | 2003-06-23 08:00 | 2003-08-08 17:00 |  | 0d |  |  | 344h |
| 176 | 1.2.3.1.1 | **Campaign Maps** | 35d | 2003-06-23 08:00 | 2003-08-08 17:00 |  | 0d |  |  | 280h |
| 177 | 1.2.3.1.1.1 | **Exterior maps** | 35d | 2003-06-23 08:00 | 2003-08-08 17:00 |  | 0d |  |  | 280h |
| 178 | 1.2.3.1.1.1.1 | **Map 1** | 1.5d | 2003-06-23 08:00 | 2003-06-24 12:00 |  | 0d |  |  | 12h |
| 179 | 1.2.3.1.1.1.1.1 | Build map | 1d | 2003-06-23 08:00 | 2003-06-23 17:00 |  | 0d |  | Steven Taylor | 8h |
| 180 | 1.2.3.1.1.1.1.2 | Test map | 0.5d | 2003-06-24 08:00 | 2003-06-24 12:00 | 179 | 0d |  | Steven Taylor | 4h |

| ID | WBS | Task | Duration | Start | Finish | Predecessors | Total slack | Resources | Work |
| --- | --- | --- | --- | --- | --- | --- | --- | --- | --- |
| 181 | 1.2.3.1.1.1.2 | **Map 2** | 1.5d | 2003-06-24 13:00 | 2003-06-25 17:00 | 178 | 0d |  | 12h |
| 182 | 1.2.3.1.1.1.2.1 | Build map | 1d | 2003-06-24 13:00 | 2003-06-25 12:00 |  | 0d | Steven Taylor | 8h |
| 183 | 1.2.3.1.1.1.2.2 | Test map | 0.5d | 2003-06-25 13:00 | 2003-06-25 17:00 | 182 | 0d | Steven Taylor | 4h |
| 184 | 1.2.3.1.1.1.3 | **Map 3** | 1.5d | 2003-06-26 08:00 | 2003-06-27 12:00 | 181 | 0d |  | 12h |
| 185 | 1.2.3.1.1.1.3.1 | Build map | 1d | 2003-06-26 08:00 | 2003-06-26 17:00 |  | 0d | Steven Taylor | 8h |
| 186 | 1.2.3.1.1.1.3.2 | Test map | 0.5d | 2003-06-27 08:00 | 2003-06-27 12:00 | 185 | 0d | Steven Taylor | 4h |
| 187 | 1.2.3.1.1.1.4 | **map 4** | 1.5d | 2003-06-27 13:00 | 2003-06-30 17:00 | 184 | 0d |  | 12h |
| 188 | 1.2.3.1.1.1.4.1 | Build map | 1d | 2003-06-27 13:00 | 2003-06-30 12:00 |  | 0d | Steven Taylor | 8h |
| 189 | 1.2.3.1.1.1.4.2 | Test map | 0.5d | 2003-06-30 13:00 | 2003-06-30 17:00 | 188 | 0d | Steven Taylor | 4h |
| 190 | 1.2.3.1.1.1.5 | **Map 5** | 1.5d | 2003-07-01 08:00 | 2003-07-02 12:00 | 187 | 0d |  | 12h |
| 191 | 1.2.3.1.1.1.5.1 | Build map | 1d | 2003-07-01 08:00 | 2003-07-01 17:00 |  | 0d | Steven Taylor | 8h |
| 192 | 1.2.3.1.1.1.5.2 | Test map | 0.5d | 2003-07-02 08:00 | 2003-07-02 12:00 | 191 | 0d | Steven Taylor | 4h |
| 193 | 1.2.3.1.1.1.6 | **Map 6** | 1.5d | 2003-07-02 13:00 | 2003-07-03 17:00 | 190 | 0d |  | 12h |
| 194 | 1.2.3.1.1.1.6.1 | Build map | 1d | 2003-07-02 13:00 | 2003-07-03 12:00 |  | 0d | Steven Taylor | 8h |
| 195 | 1.2.3.1.1.1.6.2 | Test map | 0.5d | 2003-07-03 13:00 | 2003-07-03 17:00 | 194 | 0d | Steven Taylor | 4h |
| 196 | 1.2.3.1.1.1.7 | **Map 7** | 1.5d | 2003-07-04 08:00 | 2003-07-07 12:00 | 193 | 0d |  | 12h |
| 197 | 1.2.3.1.1.1.7.1 | Build map | 1d | 2003-07-04 08:00 | 2003-07-04 17:00 |  | 0d | Steven Taylor | 8h |
| 198 | 1.2.3.1.1.1.7.2 | Test map | 0.5d | 2003-07-07 08:00 | 2003-07-07 12:00 | 197 | 0d | Steven Taylor | 4h |
| 199 | 1.2.3.1.1.1.8 | **Map 8** | 1.5d | 2003-07-07 13:00 | 2003-07-08 17:00 | 196 | 0d |  | 12h |
| 200 | 1.2.3.1.1.1.8.1 | Build map | 1d | 2003-07-07 13:00 | 2003-07-08 12:00 |  | 0d | Steven Taylor | 8h |
| 201 | 1.2.3.1.1.1.8.2 | Test map | 0.5d | 2003-07-08 13:00 | 2003-07-08 17:00 | 200 | 0d | Steven Taylor | 4h |
| 202 | 1.2.3.1.1.1.9 | **Map 9** | 1.5d | 2003-07-09 08:00 | 2003-07-10 12:00 | 199 | 0d |  | 12h |
| 203 | 1.2.3.1.1.1.9.1 | Build map | 1d | 2003-07-09 08:00 | 2003-07-09 17:00 |  | 0d | Steven Taylor | 8h |
| 204 | 1.2.3.1.1.1.9.2 | Test map | 0.5d | 2003-07-10 08:00 | 2003-07-10 12:00 | 203 | 0d | Steven Taylor | 4h |

| ID | WBS | Task | Duration | Start | Finish | Predecessors | Total slack | Resources | Work |
| --- | --- | --- | --- | --- | --- | --- | --- | --- | --- |
| 205 | 1.2.3.1.1.1.10 | **Map 10** | 1.5d | 2003-07-10 13:00 | 2003-07-11 17:00 | 202 | 0d |  | 12h |
| 206 | 1.2.3.1.1.1.10.1 | Build map | 1d | 2003-07-10 13:00 | 2003-07-11 12:00 |  | 0d | Steven Taylor | 8h |
| 207 | 1.2.3.1.1.1.10.2 | Test map | 0.5d | 2003-07-11 13:00 | 2003-07-11 17:00 | 206 | 0d | Steven Taylor | 4h |
| 208 | 1.2.3.1.1.1.11 | **Map11** | 1.5d | 2003-07-14 08:00 | 2003-07-15 12:00 | 205 | 0d |  | 12h |
| 209 | 1.2.3.1.1.1.11.1 | Build map | 1d | 2003-07-14 08:00 | 2003-07-14 17:00 |  | 0d | Steven Taylor | 8h |
| 210 | 1.2.3.1.1.1.11.2 | Test map | 0.5d | 2003-07-15 08:00 | 2003-07-15 12:00 | 209 | 0d | Steven Taylor | 4h |
| 211 | 1.2.3.1.1.1.12 | **Map 12** | 1.5d | 2003-07-15 13:00 | 2003-07-16 17:00 | 208 | 0d |  | 12h |
| 212 | 1.2.3.1.1.1.12.1 | Build map | 1d | 2003-07-15 13:00 | 2003-07-16 12:00 |  | 0d | Steven Taylor | 8h |
| 213 | 1.2.3.1.1.1.12.2 | Test map | 0.5d | 2003-07-16 13:00 | 2003-07-16 17:00 | 212 | 0d | Steven Taylor | 4h |
| 214 | 1.2.3.1.1.1.13 | **Map 13** | 1.5d | 2003-07-17 08:00 | 2003-07-18 12:00 | 211 | 0d |  | 12h |
| 215 | 1.2.3.1.1.1.13.1 | Build map | 1d | 2003-07-17 08:00 | 2003-07-17 17:00 |  | 0d | Steven Taylor | 8h |
| 216 | 1.2.3.1.1.1.13.2 | Test map | 0.5d | 2003-07-18 08:00 | 2003-07-18 12:00 | 215 | 0d | Steven Taylor | 4h |
| 217 | 1.2.3.1.1.1.14 | **Map 14** | 1.5d | 2003-07-18 13:00 | 2003-07-21 17:00 | 214 | 0d |  | 12h |
| 218 | 1.2.3.1.1.1.14.1 | Build map | 1d | 2003-07-18 13:00 | 2003-07-21 12:00 |  | 0d | Steven Taylor | 8h |
| 219 | 1.2.3.1.1.1.14.2 | Test map | 0.5d | 2003-07-21 13:00 | 2003-07-21 17:00 | 218 | 0d | Steven Taylor | 4h |
| 220 | 1.2.3.1.1.1.15 | **map 15** | 1.5d | 2003-07-22 08:00 | 2003-07-23 12:00 | 217 | 0d |  | 12h |
| 221 | 1.2.3.1.1.1.15.1 | Build map | 1d | 2003-07-22 08:00 | 2003-07-22 17:00 |  | 0d | Steven Taylor | 8h |
| 222 | 1.2.3.1.1.1.15.2 | Test map | 0.5d | 2003-07-23 08:00 | 2003-07-23 12:00 | 221 | 0d | Steven Taylor | 4h |
| 223 | 1.2.3.1.1.1.16 | **Map 16** | 1d | 2003-07-23 13:00 | 2003-07-24 12:00 | 220 | 0d |  | 8h |
| 224 | 1.2.3.1.1.1.16.1 | Build map | 0.5d | 2003-07-23 13:00 | 2003-07-23 17:00 |  | 0d | Steven Taylor | 4h |
| 225 | 1.2.3.1.1.1.16.2 | Test map | 0.5d | 2003-07-24 08:00 | 2003-07-24 12:00 | 224 | 0d | Steven Taylor | 4h |
| 226 | 1.2.3.1.1.1.17 | **map 17** | 1.5d | 2003-07-24 13:00 | 2003-07-25 17:00 | 223 | 0d |  | 12h |
| 227 | 1.2.3.1.1.1.17.1 | Build map | 1d | 2003-07-24 13:00 | 2003-07-25 12:00 |  | 0d | Steven Taylor | 8h |
| 228 | 1.2.3.1.1.1.17.2 | Test map | 0.5d | 2003-07-25 13:00 | 2003-07-25 17:00 | 227 | 0d | Steven Taylor | 4h |

| ID | WBS | Task | Duration | Start | Finish | Predecessors | Total slack | Free slack | Resources | Work |
| --- | --- | --- | --- | --- | --- | --- | --- | --- | --- | --- |
| 229 | 1.2.3.1.1.1.18 | **Map 18** | 1.5d | 2003-07-28 08:00 | 2003-07-29 12:00 | 226 | 0d |  |  | 12h |
| 230 | 1.2.3.1.1.1.18.1 | Build map | 1d | 2003-07-28 08:00 | 2003-07-28 17:00 |  | 0d |  | Steven Taylor | 8h |
| 231 | 1.2.3.1.1.1.18.2 | Test map | 0.5d | 2003-07-29 08:00 | 2003-07-29 12:00 | 230 | 0d |  | Steven Taylor | 4h |
| 232 | 1.2.3.1.1.1.19 | **Map 19** | 1d | 2003-07-29 13:00 | 2003-07-30 12:00 | 229 | 0d |  |  | 8h |
| 233 | 1.2.3.1.1.1.19.1 | Build map | 0.5d | 2003-07-29 13:00 | 2003-07-29 17:00 |  | 0d |  | Steven Taylor | 4h |
| 234 | 1.2.3.1.1.1.19.2 | Test map | 0.5d | 2003-07-30 08:00 | 2003-07-30 12:00 | 233 | 0d |  | Steven Taylor | 4h |
| 235 | 1.2.3.1.1.1.20 | **Map 20** | 1.5d | 2003-07-30 13:00 | 2003-07-31 17:00 | 232 | 0d |  |  | 12h |
| 236 | 1.2.3.1.1.1.20.1 | Build map | 1d | 2003-07-30 13:00 | 2003-07-31 12:00 |  | 0d |  | Steven Taylor | 8h |
| 237 | 1.2.3.1.1.1.20.2 | Test map | 0.5d | 2003-07-31 13:00 | 2003-07-31 17:00 | 236 | 0d |  | Steven Taylor | 4h |
| 238 | 1.2.3.1.1.1.21 | **Map 21** | 1.5d | 2003-08-01 08:00 | 2003-08-04 12:00 | 235 | 0d |  |  | 12h |
| 239 | 1.2.3.1.1.1.21.1 | Build map | 1d | 2003-08-01 08:00 | 2003-08-01 17:00 |  | 0d |  | Steven Taylor | 8h |
| 240 | 1.2.3.1.1.1.21.2 | Test map | 0.5d | 2003-08-04 08:00 | 2003-08-04 12:00 | 239 | 0d |  | Steven Taylor | 4h |
| 241 | 1.2.3.1.1.1.22 | **Map 22** | 1.5d | 2003-08-04 13:00 | 2003-08-05 17:00 | 238 | 0d |  |  | 12h |
| 242 | 1.2.3.1.1.1.22.1 | Build map | 1d | 2003-08-04 13:00 | 2003-08-05 12:00 |  | 0d |  | Steven Taylor | 8h |
| 243 | 1.2.3.1.1.1.22.2 | Test map | 0.5d | 2003-08-05 13:00 | 2003-08-05 17:00 | 242 | 0d |  | Steven Taylor | 4h |
| 244 | 1.2.3.1.1.1.23 | **Map 23** | 1.5d | 2003-08-06 08:00 | 2003-08-07 12:00 | 241 | 0d |  |  | 12h |
| 245 | 1.2.3.1.1.1.23.1 | Build map | 1d | 2003-08-06 08:00 | 2003-08-06 17:00 |  | 0d |  | Steven Taylor | 8h |
| 246 | 1.2.3.1.1.1.23.2 | Test map | 0.5d | 2003-08-07 08:00 | 2003-08-07 12:00 | 245 | 0d |  | Steven Taylor | 4h |
| 247 | 1.2.3.1.1.1.24 | **map 24** | 1.5d | 2003-08-07 13:00 | 2003-08-08 17:00 | 244 | 0d |  |  | 12h |
| 248 | 1.2.3.1.1.1.24.1 | Build map | 1d | 2003-08-07 13:00 | 2003-08-08 12:00 |  | 0d |  | Steven Taylor | 8h |
| 249 | 1.2.3.1.1.1.24.2 | Test map | 0.5d | 2003-08-08 13:00 | 2003-08-08 17:00 | 248 | 0d |  | Steven Taylor | 4h |
| 250 | 1.2.3.1.2 | **Interior Maps** | 8d | 2003-06-23 08:00 | 2003-07-02 17:00 |  | 27d |  |  | 64h |
| 251 | 1.2.3.1.2.1 | **Donovan Howard Interior** | 1d | 2003-06-23 08:00 | 2003-06-23 17:00 |  | 27d | 0d |  | 8h |
| 252 | 1.2.3.1.2.1.1 | Build map | 0.5d | 2003-06-23 08:00 | 2003-06-23 12:00 |  | 27d | 0d | Steven Taylor | 4h |
| 253 | 1.2.3.1.2.1.2 | Test map | 0.5d | 2003-06-23 13:00 | 2003-06-23 17:00 | 252 | 27d |  | Steven Taylor | 4h |

| ID | WBS | Task | Duration | Start | Finish | Predecessors | Total slack | Free slack | Resources | Work |
| --- | --- | --- | --- | --- | --- | --- | --- | --- | --- | --- |
| 254 | 1.2.3.1.2.2 | **Sue Lee Interior** | 1d | 2003-06-24 08:00 | 2003-06-24 17:00 | 251 | 27d | 0d |  | 8h |
| 255 | 1.2.3.1.2.2.1 | Build map | 0.5d | 2003-06-24 08:00 | 2003-06-24 12:00 |  | 27d | 0d | Steven Taylor | 4h |
| 256 | 1.2.3.1.2.2.2 | Test map | 0.5d | 2003-06-24 13:00 | 2003-06-24 17:00 | 255 | 27d |  | Steven Taylor | 4h |
| 257 | 1.2.3.1.2.3 | **Yu tusumi Interior** | 1d | 2003-06-25 08:00 | 2003-06-25 17:00 | 254 | 27d | 0d |  | 8h |
| 258 | 1.2.3.1.2.3.1 | Build map | 0.5d | 2003-06-25 08:00 | 2003-06-25 12:00 |  | 27d | 0d | Steven Taylor | 4h |
| 259 | 1.2.3.1.2.3.2 | Test map | 0.5d | 2003-06-25 13:00 | 2003-06-25 17:00 | 258 | 27d |  | Steven Taylor | 4h |
| 260 | 1.2.3.1.2.4 | **Hugh Anderson Interior** | 1d | 2003-06-26 08:00 | 2003-06-26 17:00 | 257 | 27d | 0d |  | 8h |
| 261 | 1.2.3.1.2.4.1 | Build map | 0.5d | 2003-06-26 08:00 | 2003-06-26 12:00 |  | 27d | 0d | Steven Taylor | 4h |
| 262 | 1.2.3.1.2.4.2 | Test map | 0.5d | 2003-06-26 13:00 | 2003-06-26 17:00 | 261 | 27d |  | Steven Taylor | 4h |
| 263 | 1.2.3.1.2.5 | **Kurt Rollins Interior** | 1d | 2003-06-27 08:00 | 2003-06-27 17:00 | 260 | 27d | 0d |  | 8h |
| 264 | 1.2.3.1.2.5.1 | Build map | 0.5d | 2003-06-27 08:00 | 2003-06-27 12:00 |  | 27d | 0d | Steven Taylor | 4h |
| 265 | 1.2.3.1.2.5.2 | Test map | 0.5d | 2003-06-27 13:00 | 2003-06-27 17:00 | 264 | 27d |  | Steven Taylor | 4h |
| 266 | 1.2.3.1.2.6 | **Mr. K Interior** | 1d | 2003-06-30 08:00 | 2003-06-30 17:00 | 263 | 27d | 0d |  | 8h |
| 267 | 1.2.3.1.2.6.1 | Build map | 0.5d | 2003-06-30 08:00 | 2003-06-30 12:00 |  | 27d | 0d | Steven Taylor | 4h |
| 268 | 1.2.3.1.2.6.2 | Test map | 0.5d | 2003-06-30 13:00 | 2003-06-30 17:00 | 267 | 27d |  | Steven Taylor | 4h |
| 269 | 1.2.3.1.2.7 | **Charles Nathan Smith interior** | 1d | 2003-07-01 08:00 | 2003-07-01 17:00 | 266 | 27d | 0d |  | 8h |
| 270 | 1.2.3.1.2.7.1 | Build map | 0.5d | 2003-07-01 08:00 | 2003-07-01 12:00 |  | 27d | 0d | Steven Taylor | 4h |
| 271 | 1.2.3.1.2.7.2 | Test map | 0.5d | 2003-07-01 13:00 | 2003-07-01 17:00 | 270 | 27d |  | Steven Taylor | 4h |
| 272 | 1.2.3.1.2.8 | **Lord Excelsior interior** | 1d | 2003-07-02 08:00 | 2003-07-02 17:00 | 269 | 27d |  |  | 8h |
| 273 | 1.2.3.1.2.8.1 | Build map | 0.5d | 2003-07-02 08:00 | 2003-07-02 12:00 |  | 27d | 0d | Steven Taylor | 4h |
| 274 | 1.2.3.1.2.8.2 | Test map | 0.5d | 2003-07-02 13:00 | 2003-07-02 17:00 | 273 | 27d |  | Steven Taylor | 4h |
| 276 | 1.3 | **BETA** | 35d | 2003-08-11 08:00 | 2003-09-26 17:00 | 9 | 0d |  |  | 1664h |
| 277 | 1.3.1 | **Code** | 35d | 2003-08-11 08:00 | 2003-09-26 17:00 |  | 0d |  |  | 560h |
| 278 | 1.3.1.1 | **AI decision making** | 10d | 2003-08-11 08:00 | 2003-08-22 17:00 |  | 0d |  |  | 80h |
| 279 | 1.3.1.1.1 | Put in AI project architecture | 5d | 2003-08-11 08:00 | 2003-08-15 17:00 |  | 0d |  | Will Hanson | 40h |
| 280 | 1.3.1.1.2 | project generation | 5d | 2003-08-18 08:00 | 2003-08-22 17:00 | 279 | 0d |  | Will Hanson | 40h |

Notes:
- 276: Beta. The Beta submission will have final Art quality assets, and will be a complete game.

| ID | WBS | Task | Duration | Start | Finish | Predecessors | Total slack | Resources | Work |
| --- | --- | --- | --- | --- | --- | --- | --- | --- | --- |
| 281 | 1.3.1.2 | **Game Save** | 6d | 2003-08-11 08:00 | 2003-08-18 17:00 |  | 0d |  | 48h |
| 282 | 1.3.1.2.1 | Work on profile saving | 2d | 2003-08-11 08:00 | 2003-08-12 17:00 |  | 0d | Martin piper | 16h |
| 283 | 1.3.1.2.2 | Game save slots (3X) | 1d | 2003-08-13 08:00 | 2003-08-13 17:00 | 282 | 0d | Martin piper | 8h |
| 284 | 1.3.1.2.3 | MMC support for saving | 1d | 2003-08-14 08:00 | 2003-08-14 17:00 | 283 | 0d | Martin piper | 8h |
| 285 | 1.3.1.2.4 | Testing | 2d | 2003-08-15 08:00 | 2003-08-18 17:00 | 284 | 0d | Martin piper | 16h |
| 286 | 1.3.1.3 | **Game Logic** | 5d | 2003-09-15 08:00 | 2003-09-19 17:00 | 314 | 0d |  | 40h |
| 287 | 1.3.1.3.1 | Final Pass Game logic | 5d | 2003-09-15 08:00 | 2003-09-19 17:00 |  | 0d | Will Hanson | 40h |
| 288 | 1.3.1.4 | **Sound code** | 3d | 2003-08-27 08:00 | 2003-08-29 17:00 | 290 | 0d |  | 24h |
| 289 | 1.3.1.4.1 | ADPCM Compression | 3d | 2003-08-27 08:00 | 2003-08-29 17:00 |  | 0d | Martin piper | 24h |
| 290 | 1.3.1.5 | **Front-End** | 6d | 2003-08-19 08:00 | 2003-08-26 17:00 | 281 | 0d |  | 48h |
| 291 | 1.3.1.5.1 | Menu screen dialogue | 1d | 2003-08-19 08:00 | 2003-08-19 17:00 |  | 0d | Martin piper | 8h |
| 292 | 1.3.1.5.2 | Main Option screen | 1d | 2003-08-20 08:00 | 2003-08-20 17:00 | 291 | 0d | Martin piper | 8h |
| 293 | 1.3.1.5.3 | Campaign Menu Screen | 1d | 2003-08-21 08:00 | 2003-08-21 17:00 | 292 | 0d | Martin piper | 8h |
| 294 | 1.3.1.5.4 | Options screen | 1d | 2003-08-22 08:00 | 2003-08-22 17:00 | 293 | 0d | Martin piper | 8h |
| 295 | 1.3.1.5.5 | Multiplayer Skirmish Screen | 2d | 2003-08-25 08:00 | 2003-08-26 17:00 | 294 | 0d | Martin piper | 16h |
| 296 | 1.3.1.6 | **Optimisations** | 20d | 2003-09-01 08:00 | 2003-09-26 17:00 | 288 | 0d |  | 160h |
| 297 | 1.3.1.6.1 | Fixed point maths ASM optimisation | 1d | 2003-09-01 08:00 | 2003-09-01 17:00 |  | 0d | Martin piper | 8h |
| 298 | 1.3.1.6.2 | Function optimisation of is in, icos, isqrt functions | 1d | 2003-09-02 08:00 | 2003-09-02 17:00 | 297 | 0d | Martin piper | 8h |
| 299 | 1.3.1.6.3 | Vector maths optimisation | 1d | 2003-09-03 08:00 | 2003-09-03 17:00 | 298 | 0d | Martin piper | 8h |
| 300 | 1.3.1.6.4 | Matrix maths optimisation | 1d | 2003-09-04 08:00 | 2003-09-04 17:00 | 299 | 0d | Martin piper | 8h |
| 301 | 1.3.1.6.5 | Polygon plotting scanline optimisation | 3d | 2003-09-05 08:00 | 2003-09-09 17:00 | 300 | 0d | Martin piper | 24h |
| 302 | 1.3.1.6.6 | Polygon scanline conversion optimisation | 3d | 2003-09-10 08:00 | 2003-09-12 17:00 | 301 | 0d | Martin piper | 24h |
| 303 | 1.3.1.6.7 | Polygon clipping with emitted edge cache | 3d | 2003-09-15 08:00 | 2003-09-17 17:00 | 302 | 0d | Martin piper | 24h |
| 304 | 1.3.1.6.8 | Model draw memory transfer optimisation | 3d | 2003-09-18 08:00 | 2003-09-22 17:00 | 303 | 0d | Martin piper | 24h |
| 305 | 1.3.1.6.9 | Alter the render call to just include state information that is used for the bucket sort | 2d | 2003-09-23 08:00 | 2003-09-24 17:00 | 304 | 0d | Martin piper | 16h |
| 306 | 1.3.1.6.10 | Test z-buffer drawing speed as opposed to z-sort | 2d | 2003-09-25 08:00 | 2003-09-26 17:00 | 305 | 0d | Martin piper | 16h |

| ID | WBS | Task | Duration | Start | Finish | Predecessors | Total slack | Resources | Work |
| --- | --- | --- | --- | --- | --- | --- | --- | --- | --- |
| 307 | 1.3.1.7 | **AI decision making for battle map screen** | 12d | 2003-08-25 08:00 | 2003-09-09 17:00 | 278 | 0d |  | 96h |
| 308 | 1.3.1.7.1 | project prioritisation | 4d | 2003-08-25 08:00 | 2003-08-28 17:00 |  | 0d | Will Hanson | 32h |
| 309 | 1.3.1.7.2 | project assignment | 4d | 2003-08-29 08:00 | 2003-09-03 17:00 | 308 | 0d | Will Hanson | 32h |
| 310 | 1.3.1.7.3 | project execution | 4d | 2003-09-04 08:00 | 2003-09-09 17:00 | 309 | 0d | Will Hanson | 32h |
| 311 | 1.3.1.8 | **Tutorial** | 5d | 2003-09-22 08:00 | 2003-09-26 17:00 | 286 | 0d |  | 40h |
| 312 | 1.3.1.8.1 | Tutorial Scripting design & implementation | 3d | 2003-09-22 08:00 | 2003-09-24 17:00 |  | 0d | Will Hanson | 24h |
| 313 | 1.3.1.8.2 | Ensure entity support works with Dialogue translations | 2d | 2003-09-25 08:00 | 2003-09-26 17:00 | 312 | 0d | Will Hanson | 16h |
| 314 | 1.3.1.9 | **Final Pass Attribute Functionality** | 3d | 2003-09-10 08:00 | 2003-09-12 17:00 | 307 | 0d |  | 24h |
| 315 | 1.3.1.9.1 | Entity Attribute Functionality | 3d | 2003-09-10 08:00 | 2003-09-12 17:00 |  | 0d | Will Hanson | 24h |
| 316 | 1.3.2 | **ART** | 35d | 2003-08-11 08:00 | 2003-09-26 17:00 |  | 0d |  | 824h |
| 317 | 1.3.2.1 | **Animations** | 32d | 2003-08-11 08:00 | 2003-09-23 17:00 |  | 0d |  | 256h |
| 318 | 1.3.2.1.1 | **Donovan Howard** | 4d | 2003-08-11 08:00 | 2003-08-14 17:00 |  | 0d |  | 32h |
| 319 | 1.3.2.1.1.1 | Bone Character | 1d | 2003-08-11 08:00 | 2003-08-11 17:00 |  | 0d | Stuart Scott | 8h |
| 320 | 1.3.2.1.1.2 | **Animations** | 3d | 2003-08-12 08:00 | 2003-08-14 17:00 | 319 | 0d |  | 24h |
| 321 | 1.3.2.1.1.2.1 | Winning Animation cut scene | 1d | 2003-08-12 08:00 | 2003-08-12 17:00 |  | 0d | Stuart Scott | 8h |
| 322 | 1.3.2.1.1.2.2 | Losing animation cut scene | 1d | 2003-08-13 08:00 | 2003-08-13 17:00 | 321 | 0d | Stuart Scott | 8h |
| 323 | 1.3.2.1.1.2.3 | Office animations | 1d | 2003-08-14 08:00 | 2003-08-14 17:00 | 322 | 0d | Stuart Scott | 8h |
| 324 | 1.3.2.1.2 | **Sue Lee** | 4d | 2003-08-15 08:00 | 2003-08-20 17:00 | 318 | 0d |  | 32h |
| 325 | 1.3.2.1.2.1 | Bone Character | 1d | 2003-08-15 08:00 | 2003-08-15 17:00 |  | 0d | Stuart Scott | 8h |
| 326 | 1.3.2.1.2.2 | **Animations** | 3d | 2003-08-18 08:00 | 2003-08-20 17:00 | 325 | 0d |  | 24h |
| 327 | 1.3.2.1.2.2.1 | Winning Animation cut scene | 1d | 2003-08-18 08:00 | 2003-08-18 17:00 |  | 0d | Stuart Scott | 8h |
| 328 | 1.3.2.1.2.2.2 | Losing animation cut scene | 1d | 2003-08-19 08:00 | 2003-08-19 17:00 | 327 | 0d | Stuart Scott | 8h |
| 329 | 1.3.2.1.2.2.3 | Office animations | 1d | 2003-08-20 08:00 | 2003-08-20 17:00 | 328 | 0d | Stuart Scott | 8h |
| 330 | 1.3.2.1.3 | **Lord Excelsior** | 4d | 2003-08-21 08:00 | 2003-08-26 17:00 | 324 | 0d |  | 32h |
| 331 | 1.3.2.1.3.1 | Bone Character | 1d | 2003-08-21 08:00 | 2003-08-21 17:00 |  | 0d | Stuart Scott | 8h |

| ID | WBS | Task | Duration | Start | Finish | Predecessors | Total slack | Resources | Work |
| --- | --- | --- | --- | --- | --- | --- | --- | --- | --- |
| 332 | 1.3.2.1.3.2 | **Animations** | 3d | 2003-08-22 08:00 | 2003-08-26 17:00 | 331 | 0d |  | 24h |
| 333 | 1.3.2.1.3.2.1 | Winning Animation cut scene | 1d | 2003-08-22 08:00 | 2003-08-22 17:00 |  | 0d | Stuart Scott | 8h |
| 334 | 1.3.2.1.3.2.2 | Losing animation cut scene | 1d | 2003-08-25 08:00 | 2003-08-25 17:00 | 333 | 0d | Stuart Scott | 8h |
| 335 | 1.3.2.1.3.2.3 | Office animations | 1d | 2003-08-26 08:00 | 2003-08-26 17:00 | 334 | 0d | Stuart Scott | 8h |
| 336 | 1.3.2.1.4 | **Yu Tosumi** | 4d | 2003-08-27 08:00 | 2003-09-01 17:00 | 330 | 0d |  | 32h |
| 337 | 1.3.2.1.4.1 | Bone Character | 1d | 2003-08-27 08:00 | 2003-08-27 17:00 |  | 0d | Stuart Scott | 8h |
| 338 | 1.3.2.1.4.2 | **Animations** | 3d | 2003-08-28 08:00 | 2003-09-01 17:00 | 337 | 0d |  | 24h |
| 339 | 1.3.2.1.4.2.1 | Winning Animation cut scene | 1d | 2003-08-28 08:00 | 2003-08-28 17:00 |  | 0d | Stuart Scott | 8h |
| 340 | 1.3.2.1.4.2.2 | Losing animation cut scene | 1d | 2003-08-29 08:00 | 2003-08-29 17:00 | 339 | 0d | Stuart Scott | 8h |
| 341 | 1.3.2.1.4.2.3 | Office animations | 1d | 2003-09-01 08:00 | 2003-09-01 17:00 | 340 | 0d | Stuart Scott | 8h |
| 342 | 1.3.2.1.5 | **Kurt Rollins** | 4d | 2003-09-02 08:00 | 2003-09-05 17:00 | 336 | 0d |  | 32h |
| 343 | 1.3.2.1.5.1 | Bone Character | 1d | 2003-09-02 08:00 | 2003-09-02 17:00 |  | 0d | Stuart Scott | 8h |
| 344 | 1.3.2.1.5.2 | **Animations** | 3d | 2003-09-03 08:00 | 2003-09-05 17:00 | 343 | 0d |  | 24h |
| 345 | 1.3.2.1.5.2.1 | Winning Animation cut scene | 1d | 2003-09-03 08:00 | 2003-09-03 17:00 |  | 0d | Stuart Scott | 8h |
| 346 | 1.3.2.1.5.2.2 | Losing animation cut scene | 1d | 2003-09-04 08:00 | 2003-09-04 17:00 | 345 | 0d | Stuart Scott | 8h |
| 347 | 1.3.2.1.5.2.3 | Office animations | 1d | 2003-09-05 08:00 | 2003-09-05 17:00 | 346 | 0d | Stuart Scott | 8h |
| 348 | 1.3.2.1.6 | **Hugh Anderson** | 4d | 2003-09-08 08:00 | 2003-09-11 17:00 | 342 | 0d |  | 32h |
| 349 | 1.3.2.1.6.1 | Bone Character | 1d | 2003-09-08 08:00 | 2003-09-08 17:00 |  | 0d | Stuart Scott | 8h |
| 350 | 1.3.2.1.6.2 | **Animations** | 3d | 2003-09-09 08:00 | 2003-09-11 17:00 | 349 | 0d |  | 24h |
| 351 | 1.3.2.1.6.2.1 | Winning Animation cut scene | 1d | 2003-09-09 08:00 | 2003-09-09 17:00 |  | 0d | Stuart Scott | 8h |
| 352 | 1.3.2.1.6.2.2 | Losing animation cut scene | 1d | 2003-09-10 08:00 | 2003-09-10 17:00 | 351 | 0d | Stuart Scott | 8h |
| 353 | 1.3.2.1.6.2.3 | Office animations | 1d | 2003-09-11 08:00 | 2003-09-11 17:00 | 352 | 0d | Stuart Scott | 8h |
| 354 | 1.3.2.1.7 | **Mr. K** | 4d | 2003-09-12 08:00 | 2003-09-17 17:00 | 348 | 0d |  | 32h |
| 355 | 1.3.2.1.7.1 | Bone Character | 1d | 2003-09-12 08:00 | 2003-09-12 17:00 |  | 0d | Stuart Scott | 8h |

| ID | WBS | Task | Duration | Start | Finish | Predecessors | Total slack | Resources | Work |
| --- | --- | --- | --- | --- | --- | --- | --- | --- | --- |
| 356 | 1.3.2.1.7.2 | **Animations** | 3d | 2003-09-15 08:00 | 2003-09-17 17:00 | 355 | 0d |  | 24h |
| 357 | 1.3.2.1.7.2.1 | Winning Animation cut scene | 1d | 2003-09-15 08:00 | 2003-09-15 17:00 |  | 0d | Stuart Scott | 8h |
| 358 | 1.3.2.1.7.2.2 | Losing animation cut scene | 1d | 2003-09-16 08:00 | 2003-09-16 17:00 | 357 | 0d | Stuart Scott | 8h |
| 359 | 1.3.2.1.7.2.3 | Office animations | 1d | 2003-09-17 08:00 | 2003-09-17 17:00 | 358 | 0d | Stuart Scott | 8h |
| 360 | 1.3.2.1.8 | **Charles Nathan Smith** | 4d | 2003-09-18 08:00 | 2003-09-23 17:00 | 354 | 0d |  | 32h |
| 361 | 1.3.2.1.8.1 | Bone Character | 1d | 2003-09-18 08:00 | 2003-09-18 17:00 |  | 0d | Stuart Scott | 8h |
| 362 | 1.3.2.1.8.2 | **Animations** | 3d | 2003-09-19 08:00 | 2003-09-23 17:00 | 361 | 0d |  | 24h |
| 363 | 1.3.2.1.8.2.1 | Winning Animation cut scene | 1d | 2003-09-19 08:00 | 2003-09-19 17:00 |  | 0d | Stuart Scott | 8h |
| 364 | 1.3.2.1.8.2.2 | Losing animation cut scene | 1d | 2003-09-22 08:00 | 2003-09-22 17:00 | 363 | 0d | Stuart Scott | 8h |
| 365 | 1.3.2.1.8.2.3 | Office animations | 1d | 2003-09-23 08:00 | 2003-09-23 17:00 | 364 | 0d | Stuart Scott | 8h |
| 366 | 1.3.2.2 | **Additional Cut scenes** | 3d | 2003-09-24 08:00 | 2003-09-26 17:00 | 360 | 0d |  | 24h |
| 367 | 1.3.2.2.1 | Scene setting scenes | 3d | 2003-09-24 08:00 | 2003-09-26 17:00 |  | 0d | Stuart Scott | 24h |
| 368 | 1.3.2.3 | **Campaign map Graphics** | 6d | 2003-08-11 08:00 | 2003-08-18 17:00 |  | 0d |  | 48h |
| 369 | 1.3.2.3.1 | background map graphics | 2d | 2003-08-11 08:00 | 2003-08-12 17:00 |  | 0d | Douglas hickmore | 16h |
| 370 | 1.3.2.3.2 | Sector graphics | 2d | 2003-08-13 08:00 | 2003-08-14 17:00 | 369 | 0d | Douglas hickmore | 16h |
| 371 | 1.3.2.3.3 | Arrow graphics | 1d | 2003-08-15 08:00 | 2003-08-15 17:00 | 370 | 0d | Douglas hickmore | 8h |
| 372 | 1.3.2.3.4 | Unit hi-light graphics | 1d | 2003-08-18 08:00 | 2003-08-18 17:00 | 371 | 0d | Douglas hickmore | 8h |
| 373 | 1.3.2.4 | **Game over screens** | 4d | 2003-09-17 08:00 | 2003-09-22 17:00 | 383 | 0d |  | 32h |
| 374 | 1.3.2.4.1 | game over screen (lose) | 2d | 2003-09-17 08:00 | 2003-09-18 17:00 |  | 0d | Douglas hickmore | 16h |
| 375 | 1.3.2.4.2 | Game over screen Win | 2d | 2003-09-19 08:00 | 2003-09-22 17:00 | 374 | 0d | Douglas hickmore | 16h |
| 376 | 1.3.2.5 | **Office Scenes** | 4d | 2003-09-23 08:00 | 2003-09-26 17:00 | 373 | 0d |  | 32h |
| 377 | 1.3.2.5.1 | **Office window View** | 2d | 2003-09-23 08:00 | 2003-09-24 17:00 |  | 0d |  | 16h |
| 378 | 1.3.2.5.1.1 | Window view Night | 0.5d | 2003-09-23 08:00 | 2003-09-23 12:00 |  | 0d | Douglas hickmore | 4h |
| 379 | 1.3.2.5.1.2 | Window view Morning | 0.5d | 2003-09-23 13:00 | 2003-09-23 17:00 | 378 | 0d | Douglas hickmore | 4h |
| 380 | 1.3.2.5.1.3 | Window view midday | 0.5d | 2003-09-24 08:00 | 2003-09-24 12:00 | 379 | 0d | Douglas hickmore | 4h |
| 381 | 1.3.2.5.1.4 | Window view Evening | 0.5d | 2003-09-24 13:00 | 2003-09-24 17:00 | 380 | 0d | Douglas hickmore | 4h |
| 382 | 1.3.2.5.2 | Final Pass Office Graphics (including desk reflections etc) | 2d | 2003-09-25 08:00 | 2003-09-26 17:00 | 381 | 0d | Douglas hickmore | 16h |

| ID | WBS | Task | Duration | Start | Finish | Predecessors | Total slack | Free slack | Resources | Work |
| --- | --- | --- | --- | --- | --- | --- | --- | --- | --- | --- |
| 383 | 1.3.2.6 | **Attract mode** | 5d | 2003-09-10 08:00 | 2003-09-16 17:00 | 389 | 0d |  |  | 40h |
| 384 | 1.3.2.6.1 | Story board | 1d | 2003-09-10 08:00 | 2003-09-10 17:00 |  | 0d |  | Douglas hickmore | 8h |
| 385 | 1.3.2.6.2 | Attract mode graphics | 2d | 2003-09-11 08:00 | 2003-09-12 17:00 | 384 | 0d |  | Douglas hickmore | 16h |
| 386 | 1.3.2.6.3 | Morpheme logo | 0.5d | 2003-09-15 08:00 | 2003-09-15 12:00 | 385 | 0d |  | Douglas hickmore | 4h |
| 387 | 1.3.2.6.4 | Nokia Logo | 0.5d | 2003-09-15 13:00 | 2003-09-15 17:00 | 386 | 0d |  | Douglas hickmore | 4h |
| 388 | 1.3.2.6.5 | Title screen graphics | 1d | 2003-09-16 08:00 | 2003-09-16 17:00 | 387 | 0d |  | Douglas hickmore | 8h |
| 389 | 1.3.2.7 | **Main Gangsters 2D work** | 16d | 2003-08-19 08:00 | 2003-09-09 17:00 | 368 | 0d |  |  | 128h |
| 390 | 1.3.2.7.1 | Donovan Howard | 2d | 2003-08-19 08:00 | 2003-08-20 17:00 |  | 0d |  | Douglas hickmore | 16h |
| 391 | 1.3.2.7.2 | Sue lee | 2d | 2003-08-21 08:00 | 2003-08-22 17:00 | 390 | 0d |  | Douglas hickmore | 16h |
| 392 | 1.3.2.7.3 | Hugh Anderson | 2d | 2003-08-25 08:00 | 2003-08-26 17:00 | 391 | 0d |  | Douglas hickmore | 16h |
| 393 | 1.3.2.7.4 | Charles Nathan Smith | 2d | 2003-08-27 08:00 | 2003-08-28 17:00 | 392 | 0d |  | Douglas hickmore | 16h |
| 394 | 1.3.2.7.5 | Mr. K | 2d | 2003-08-29 08:00 | 2003-09-01 17:00 | 393 | 0d |  | Douglas hickmore | 16h |
| 395 | 1.3.2.7.6 | Kurt Rollins | 2d | 2003-09-02 08:00 | 2003-09-03 17:00 | 394 | 0d |  | Douglas hickmore | 16h |
| 396 | 1.3.2.7.7 | Yu Totsumi | 2d | 2003-09-04 08:00 | 2003-09-05 17:00 | 395 | 0d |  | Douglas hickmore | 16h |
| 397 | 1.3.2.7.8 | Lord excelsior | 2d | 2003-09-08 08:00 | 2003-09-09 17:00 | 396 | 0d |  | Douglas hickmore | 16h |
| 398 | 1.3.2.8 | **Battle scene GFX (refine gfx Cont)** | 7d | 2003-08-11 08:00 | 2003-08-19 17:00 |  | 2d | 0d |  | 56h |
| 399 | 1.3.2.8.1 | Barge | 1d | 2003-08-11 08:00 | 2003-08-11 17:00 |  | 2d | 0d | Oscar Ferrero | 8h |
| 400 | 1.3.2.8.2 | Bi-Plane | 1d | 2003-08-12 08:00 | 2003-08-12 17:00 | 399 | 2d | 0d | Oscar Ferrero | 8h |
| 401 | 1.3.2.8.3 | Fighter | 1d | 2003-08-13 08:00 | 2003-08-13 17:00 | 400 | 2d | 0d | Oscar Ferrero | 8h |
| 402 | 1.3.2.8.4 | AA Gun | 1d | 2003-08-14 08:00 | 2003-08-14 17:00 | 401 | 2d | 0d | Oscar Ferrero | 8h |
| 403 | 1.3.2.8.5 | Train | 1d | 2003-08-15 08:00 | 2003-08-15 17:00 | 402 | 2d | 0d | Oscar Ferrero | 8h |
| 404 | 1.3.2.8.6 | Airship | 1d | 2003-08-18 08:00 | 2003-08-18 17:00 | 403 | 2d | 0d | Oscar Ferrero | 8h |
| 405 | 1.3.2.8.7 | Bomb Truck | 1d | 2003-08-19 08:00 | 2003-08-19 17:00 | 404 | 2d |  | Oscar Ferrero | 8h |
| 406 | 1.3.2.9 | **Background graphics** | 10d | 2003-08-20 08:00 | 2003-09-02 17:00 | 398 | 2d | 0d |  | 80h |
| 407 | 1.3.2.9.1 | Bank | 1d | 2003-08-20 08:00 | 2003-08-20 17:00 |  | 2d | 0d | Oscar Ferrero | 8h |
| 408 | 1.3.2.9.2 | Airport | 1d | 2003-08-21 08:00 | 2003-08-21 17:00 | 407 | 2d | 0d | Oscar Ferrero | 8h |
| 409 | 1.3.2.9.3 | Sea port | 1d | 2003-08-22 08:00 | 2003-08-22 17:00 | 408 | 2d | 0d | Oscar Ferrero | 8h |
| 410 | 1.3.2.9.4 | Railway | 1d | 2003-08-25 08:00 | 2003-08-25 17:00 | 409 | 2d | 0d | Oscar Ferrero | 8h |
| 411 | 1.3.2.9.5 | Strip bar | 1d | 2003-08-26 08:00 | 2003-08-26 17:00 | 410 | 2d | 0d | Oscar Ferrero | 8h |
| 412 | 1.3.2.9.6 | casino | 1d | 2003-08-27 08:00 | 2003-08-27 17:00 | 411 | 2d | 0d | Oscar Ferrero | 8h |
| 413 | 1.3.2.9.7 | various (add list) | 4d | 2003-08-28 08:00 | 2003-09-02 17:00 | 412 | 2d |  | Oscar Ferrero | 32h |

| ID | WBS | Task | Duration | Start | Finish | Predecessors | Total slack | Free slack | Resources | Work |
| --- | --- | --- | --- | --- | --- | --- | --- | --- | --- | --- |
| 414 | 1.3.2.10 | **Office Graphics** | 16d | 2003-09-03 08:00 | 2003-09-24 17:00 | 406 | 2d |  |  | 128h |
| 415 | 1.3.2.10.1 | Yu Tutsumi office | 2d | 2003-09-03 08:00 | 2003-09-04 17:00 |  | 2d | 0d | Oscar Ferrero | 16h |
| 416 | 1.3.2.10.2 | Donovan howard office | 2d | 2003-09-05 08:00 | 2003-09-08 17:00 | 415 | 2d | 0d | Oscar Ferrero | 16h |
| 417 | 1.3.2.10.3 | Suzy lee Office | 2d | 2003-09-09 08:00 | 2003-09-10 17:00 | 416 | 2d | 0d | Oscar Ferrero | 16h |
| 418 | 1.3.2.10.4 | Charles Nathan Smith Office | 2d | 2003-09-11 08:00 | 2003-09-12 17:00 | 417 | 2d | 0d | Oscar Ferrero | 16h |
| 419 | 1.3.2.10.5 | Hugh Anderson Office | 2d | 2003-09-15 08:00 | 2003-09-16 17:00 | 418 | 2d | 0d | Oscar Ferrero | 16h |
| 420 | 1.3.2.10.6 | Mr K office | 2d | 2003-09-17 08:00 | 2003-09-18 17:00 | 419 | 2d | 0d | Oscar Ferrero | 16h |
| 421 | 1.3.2.10.7 | Kurt rollins office | 2d | 2003-09-19 08:00 | 2003-09-22 17:00 | 420 | 2d | 0d | Oscar Ferrero | 16h |
| 422 | 1.3.2.10.8 | Lord excelsior office | 2d | 2003-09-23 08:00 | 2003-09-24 17:00 | 421 | 2d |  | Oscar Ferrero | 16h |
| 423 | 1.3.3 | **DESIGN** | 35d | 2003-08-11 08:00 | 2003-09-26 17:00 |  | 0d |  |  | 280h |
| 424 | 1.3.3.1 | **Interior Maps** | 8d | 2003-08-11 08:00 | 2003-08-20 17:00 |  | 0d |  |  | 64h |
| 425 | 1.3.3.1.1 | **Donovan Howard Interior** | 1d | 2003-08-11 08:00 | 2003-08-11 17:00 |  | 0d |  |  | 8h |
| 426 | 1.3.3.1.1.1 | Build map | 0.5d | 2003-08-11 08:00 | 2003-08-11 12:00 |  | 0d |  | Steven Taylor | 4h |
| 427 | 1.3.3.1.1.2 | Test map | 0.5d | 2003-08-11 13:00 | 2003-08-11 17:00 | 426 | 0d |  | Steven Taylor | 4h |
| 428 | 1.3.3.1.2 | **Sue Lee Interior** | 1d | 2003-08-12 08:00 | 2003-08-12 17:00 | 425 | 0d |  |  | 8h |
| 429 | 1.3.3.1.2.1 | Build map | 0.5d | 2003-08-12 08:00 | 2003-08-12 12:00 |  | 0d |  | Steven Taylor | 4h |
| 430 | 1.3.3.1.2.2 | Test map | 0.5d | 2003-08-12 13:00 | 2003-08-12 17:00 | 429 | 0d |  | Steven Taylor | 4h |
| 431 | 1.3.3.1.3 | **Yu tusumi Interior** | 1d | 2003-08-13 08:00 | 2003-08-13 17:00 | 428 | 0d |  |  | 8h |
| 432 | 1.3.3.1.3.1 | Build map | 0.5d | 2003-08-13 08:00 | 2003-08-13 12:00 |  | 0d |  | Steven Taylor | 4h |
| 433 | 1.3.3.1.3.2 | Test map | 0.5d | 2003-08-13 13:00 | 2003-08-13 17:00 | 432 | 0d |  | Steven Taylor | 4h |
| 434 | 1.3.3.1.4 | **Hugh Anderson Interior** | 1d | 2003-08-14 08:00 | 2003-08-14 17:00 | 431 | 0d |  |  | 8h |
| 435 | 1.3.3.1.4.1 | Build map | 0.5d | 2003-08-14 08:00 | 2003-08-14 12:00 |  | 0d |  | Steven Taylor | 4h |
| 436 | 1.3.3.1.4.2 | Test map | 0.5d | 2003-08-14 13:00 | 2003-08-14 17:00 | 435 | 0d |  | Steven Taylor | 4h |
| 437 | 1.3.3.1.5 | **Kurt Rollins Interior** | 1d | 2003-08-15 08:00 | 2003-08-15 17:00 | 434 | 0d |  |  | 8h |
| 438 | 1.3.3.1.5.1 | Build map | 0.5d | 2003-08-15 08:00 | 2003-08-15 12:00 |  | 0d |  | Steven Taylor | 4h |
| 439 | 1.3.3.1.5.2 | Test map | 0.5d | 2003-08-15 13:00 | 2003-08-15 17:00 | 438 | 0d |  | Steven Taylor | 4h |

| ID | WBS | Task | Duration | Start | Finish | Predecessors | Total slack | Resources | Work |
| --- | --- | --- | --- | --- | --- | --- | --- | --- | --- |
| 440 | 1.3.3.1.6 | **Mr. K Interior** | 1d | 2003-08-18 08:00 | 2003-08-18 17:00 | 437 | 0d |  | 8h |
| 441 | 1.3.3.1.6.1 | Build map | 0.5d | 2003-08-18 08:00 | 2003-08-18 12:00 |  | 0d | Steven Taylor | 4h |
| 442 | 1.3.3.1.6.2 | Test map | 0.5d | 2003-08-18 13:00 | 2003-08-18 17:00 | 441 | 0d | Steven Taylor | 4h |
| 443 | 1.3.3.1.7 | **Charles Nathan Smith interior** | 1d | 2003-08-19 08:00 | 2003-08-19 17:00 | 440 | 0d |  | 8h |
| 444 | 1.3.3.1.7.1 | Build map | 0.5d | 2003-08-19 08:00 | 2003-08-19 12:00 |  | 0d | Steven Taylor | 4h |
| 445 | 1.3.3.1.7.2 | Test map | 0.5d | 2003-08-19 13:00 | 2003-08-19 17:00 | 444 | 0d | Steven Taylor | 4h |
| 446 | 1.3.3.1.8 | **Lord Excelsior interior** | 1d | 2003-08-20 08:00 | 2003-08-20 17:00 | 443 | 0d |  | 8h |
| 447 | 1.3.3.1.8.1 | Build map | 0.5d | 2003-08-20 08:00 | 2003-08-20 12:00 |  | 0d | Steven Taylor | 4h |
| 448 | 1.3.3.1.8.2 | Test map | 0.5d | 2003-08-20 13:00 | 2003-08-20 17:00 | 447 | 0d | Steven Taylor | 4h |
| 449 | 1.3.3.2 | **Multiplayer Maps** | 27d | 2003-08-21 08:00 | 2003-09-26 17:00 | 424 | 0d |  | 216h |
| 450 | 1.3.3.2.1 | **2 player Maps** | 10d | 2003-08-21 08:00 | 2003-09-03 17:00 |  | 0d |  | 80h |
| 451 | 1.3.3.2.1.1 | **2 player map 1** | 1d | 2003-08-21 08:00 | 2003-08-21 17:00 |  | 0d |  | 8h |
| 452 | 1.3.3.2.1.1.1 | Build map | 0.5d | 2003-08-21 08:00 | 2003-08-21 12:00 |  | 0d | Steven Taylor | 4h |
| 453 | 1.3.3.2.1.1.2 | Test map | 0.5d | 2003-08-21 13:00 | 2003-08-21 17:00 | 452 | 0d | Steven Taylor | 4h |
| 454 | 1.3.3.2.1.2 | **2 player map 2** | 1d | 2003-08-22 08:00 | 2003-08-22 17:00 | 451 | 0d |  | 8h |
| 455 | 1.3.3.2.1.2.1 | Build map | 0.5d | 2003-08-22 08:00 | 2003-08-22 12:00 |  | 0d | Steven Taylor | 4h |
| 456 | 1.3.3.2.1.2.2 | Test map | 0.5d | 2003-08-22 13:00 | 2003-08-22 17:00 | 455 | 0d | Steven Taylor | 4h |
| 457 | 1.3.3.2.1.3 | **2 player map 3** | 1d | 2003-08-25 08:00 | 2003-08-25 17:00 | 454 | 0d |  | 8h |
| 458 | 1.3.3.2.1.3.1 | Build map | 0.5d | 2003-08-25 08:00 | 2003-08-25 12:00 |  | 0d | Steven Taylor | 4h |
| 459 | 1.3.3.2.1.3.2 | Test map | 0.5d | 2003-08-25 13:00 | 2003-08-25 17:00 | 458 | 0d | Steven Taylor | 4h |
| 460 | 1.3.3.2.1.4 | **2 player map 4** | 1d | 2003-08-26 08:00 | 2003-08-26 17:00 | 457 | 0d |  | 8h |
| 461 | 1.3.3.2.1.4.1 | Build map | 0.5d | 2003-08-26 08:00 | 2003-08-26 12:00 |  | 0d | Steven Taylor | 4h |
| 462 | 1.3.3.2.1.4.2 | Test map | 0.5d | 2003-08-26 13:00 | 2003-08-26 17:00 | 461 | 0d | Steven Taylor | 4h |
| 463 | 1.3.3.2.1.5 | **2 player map 5** | 1d | 2003-08-27 08:00 | 2003-08-27 17:00 | 460 | 0d |  | 8h |
| 464 | 1.3.3.2.1.5.1 | Build map | 0.5d | 2003-08-27 08:00 | 2003-08-27 12:00 |  | 0d | Steven Taylor | 4h |
| 465 | 1.3.3.2.1.5.2 | Test map | 0.5d | 2003-08-27 13:00 | 2003-08-27 17:00 | 464 | 0d | Steven Taylor | 4h |

| ID | WBS | Task | Duration | Start | Finish | Predecessors | Total slack | Resources | Work |
| --- | --- | --- | --- | --- | --- | --- | --- | --- | --- |
| 466 | 1.3.3.2.1.6 | **2 player map 6** | 1d | 2003-08-28 08:00 | 2003-08-28 17:00 | 463 | 0d |  | 8h |
| 467 | 1.3.3.2.1.6.1 | Build map | 0.5d | 2003-08-28 08:00 | 2003-08-28 12:00 |  | 0d | Steven Taylor | 4h |
| 468 | 1.3.3.2.1.6.2 | Test map | 0.5d | 2003-08-28 13:00 | 2003-08-28 17:00 | 467 | 0d | Steven Taylor | 4h |
| 469 | 1.3.3.2.1.7 | **2 player map 7** | 1d | 2003-08-29 08:00 | 2003-08-29 17:00 | 466 | 0d |  | 8h |
| 470 | 1.3.3.2.1.7.1 | Build map | 0.5d | 2003-08-29 08:00 | 2003-08-29 12:00 |  | 0d | Steven Taylor | 4h |
| 471 | 1.3.3.2.1.7.2 | Test map | 0.5d | 2003-08-29 13:00 | 2003-08-29 17:00 | 470 | 0d | Steven Taylor | 4h |
| 472 | 1.3.3.2.1.8 | **2 player map 8** | 1d | 2003-09-01 08:00 | 2003-09-01 17:00 | 469 | 0d |  | 8h |
| 473 | 1.3.3.2.1.8.1 | Build map | 0.5d | 2003-09-01 08:00 | 2003-09-01 12:00 |  | 0d | Steven Taylor | 4h |
| 474 | 1.3.3.2.1.8.2 | Test map | 0.5d | 2003-09-01 13:00 | 2003-09-01 17:00 | 473 | 0d | Steven Taylor | 4h |
| 475 | 1.3.3.2.1.9 | **2 player map 9** | 1d | 2003-09-02 08:00 | 2003-09-02 17:00 | 472 | 0d |  | 8h |
| 476 | 1.3.3.2.1.9.1 | Build map | 0.5d | 2003-09-02 08:00 | 2003-09-02 12:00 |  | 0d | Steven Taylor | 4h |
| 477 | 1.3.3.2.1.9.2 | Test map | 0.5d | 2003-09-02 13:00 | 2003-09-02 17:00 | 476 | 0d | Steven Taylor | 4h |
| 478 | 1.3.3.2.1.10 | **2 player map 10** | 1d | 2003-09-03 08:00 | 2003-09-03 17:00 | 475 | 0d |  | 8h |
| 479 | 1.3.3.2.1.10.1 | Build map | 0.5d | 2003-09-03 08:00 | 2003-09-03 12:00 |  | 0d | Steven Taylor | 4h |
| 480 | 1.3.3.2.1.10.2 | Test map | 0.5d | 2003-09-03 13:00 | 2003-09-03 17:00 | 479 | 0d | Steven Taylor | 4h |
| 481 | 1.3.3.2.2 | **3 player maps** | 10d | 2003-09-04 08:00 | 2003-09-17 17:00 | 450 | 0d |  | 80h |
| 482 | 1.3.3.2.2.1 | **3 player map 1** | 1d | 2003-09-04 08:00 | 2003-09-04 17:00 |  | 0d |  | 8h |
| 483 | 1.3.3.2.2.1.1 | Build map | 0.5d | 2003-09-04 08:00 | 2003-09-04 12:00 |  | 0d | Steven Taylor | 4h |
| 484 | 1.3.3.2.2.1.2 | Test map | 0.5d | 2003-09-04 13:00 | 2003-09-04 17:00 | 483 | 0d | Steven Taylor | 4h |
| 485 | 1.3.3.2.2.2 | **3 player map 2** | 1d | 2003-09-05 08:00 | 2003-09-05 17:00 | 482 | 0d |  | 8h |
| 486 | 1.3.3.2.2.2.1 | Build map | 0.5d | 2003-09-05 08:00 | 2003-09-05 12:00 |  | 0d | Steven Taylor | 4h |
| 487 | 1.3.3.2.2.2.2 | Test map | 0.5d | 2003-09-05 13:00 | 2003-09-05 17:00 | 486 | 0d | Steven Taylor | 4h |
| 488 | 1.3.3.2.2.3 | **3 player map 3** | 1d | 2003-09-08 08:00 | 2003-09-08 17:00 | 485 | 0d |  | 8h |
| 489 | 1.3.3.2.2.3.1 | Build map | 0.5d | 2003-09-08 08:00 | 2003-09-08 12:00 |  | 0d | Steven Taylor | 4h |
| 490 | 1.3.3.2.2.3.2 | Test map | 0.5d | 2003-09-08 13:00 | 2003-09-08 17:00 | 489 | 0d | Steven Taylor | 4h |

| ID | WBS | Task | Duration | Start | Finish | Predecessors | Total slack | Resources | Work |
| --- | --- | --- | --- | --- | --- | --- | --- | --- | --- |
| 491 | 1.3.3.2.2.4 | **3 player map 4** | 1d | 2003-09-09 08:00 | 2003-09-09 17:00 | 488 | 0d |  | 8h |
| 492 | 1.3.3.2.2.4.1 | Build map | 0.5d | 2003-09-09 08:00 | 2003-09-09 12:00 |  | 0d | Steven Taylor | 4h |
| 493 | 1.3.3.2.2.4.2 | Test map | 0.5d | 2003-09-09 13:00 | 2003-09-09 17:00 | 492 | 0d | Steven Taylor | 4h |
| 494 | 1.3.3.2.2.5 | **3 player map 5** | 1d | 2003-09-10 08:00 | 2003-09-10 17:00 | 491 | 0d |  | 8h |
| 495 | 1.3.3.2.2.5.1 | Build map | 0.5d | 2003-09-10 08:00 | 2003-09-10 12:00 |  | 0d | Steven Taylor | 4h |
| 496 | 1.3.3.2.2.5.2 | Test map | 0.5d | 2003-09-10 13:00 | 2003-09-10 17:00 | 495 | 0d | Steven Taylor | 4h |
| 497 | 1.3.3.2.2.6 | **3 player map 6** | 1d | 2003-09-11 08:00 | 2003-09-11 17:00 | 494 | 0d |  | 8h |
| 498 | 1.3.3.2.2.6.1 | Build map | 0.5d | 2003-09-11 08:00 | 2003-09-11 12:00 |  | 0d | Steven Taylor | 4h |
| 499 | 1.3.3.2.2.6.2 | Test map | 0.5d | 2003-09-11 13:00 | 2003-09-11 17:00 | 498 | 0d | Steven Taylor | 4h |
| 500 | 1.3.3.2.2.7 | **3 player map 7** | 1d | 2003-09-12 08:00 | 2003-09-12 17:00 | 497 | 0d |  | 8h |
| 501 | 1.3.3.2.2.7.1 | Build map | 0.5d | 2003-09-12 08:00 | 2003-09-12 12:00 |  | 0d | Steven Taylor | 4h |
| 502 | 1.3.3.2.2.7.2 | Test map | 0.5d | 2003-09-12 13:00 | 2003-09-12 17:00 | 501 | 0d | Steven Taylor | 4h |
| 503 | 1.3.3.2.2.8 | **3 player map 8** | 1d | 2003-09-15 08:00 | 2003-09-15 17:00 | 500 | 0d |  | 8h |
| 504 | 1.3.3.2.2.8.1 | Build map | 0.5d | 2003-09-15 08:00 | 2003-09-15 12:00 |  | 0d | Steven Taylor | 4h |
| 505 | 1.3.3.2.2.8.2 | Test map | 0.5d | 2003-09-15 13:00 | 2003-09-15 17:00 | 504 | 0d | Steven Taylor | 4h |
| 506 | 1.3.3.2.2.9 | **3 player map 9** | 1d | 2003-09-16 08:00 | 2003-09-16 17:00 | 503 | 0d |  | 8h |
| 507 | 1.3.3.2.2.9.1 | Build map | 0.5d | 2003-09-16 08:00 | 2003-09-16 12:00 |  | 0d | Steven Taylor | 4h |
| 508 | 1.3.3.2.2.9.2 | Test map | 0.5d | 2003-09-16 13:00 | 2003-09-16 17:00 | 507 | 0d | Steven Taylor | 4h |
| 509 | 1.3.3.2.2.10 | **3 player map 10** | 1d | 2003-09-17 08:00 | 2003-09-17 17:00 | 506 | 0d |  | 8h |
| 510 | 1.3.3.2.2.10.1 | Build map | 0.5d | 2003-09-17 08:00 | 2003-09-17 12:00 |  | 0d | Steven Taylor | 4h |
| 511 | 1.3.3.2.2.10.2 | Test map | 0.5d | 2003-09-17 13:00 | 2003-09-17 17:00 | 510 | 0d | Steven Taylor | 4h |
| 512 | 1.3.3.2.3 | **4 Player maps** | 7d | 2003-09-18 08:00 | 2003-09-26 17:00 | 481 | 0d |  | 56h |
| 513 | 1.3.3.2.3.1 | **4 player map 1** | 1d | 2003-09-18 08:00 | 2003-09-18 17:00 |  | 0d |  | 8h |
| 514 | 1.3.3.2.3.1.1 | Build map | 0.5d | 2003-09-18 08:00 | 2003-09-18 12:00 |  | 0d | Steven Taylor | 4h |
| 515 | 1.3.3.2.3.1.2 | Test map | 0.5d | 2003-09-18 13:00 | 2003-09-18 17:00 | 514 | 0d | Steven Taylor | 4h |

| ID | WBS | Task | Duration | Start | Finish | Predecessors | Total slack | Resources | Work |
| --- | --- | --- | --- | --- | --- | --- | --- | --- | --- |
| 516 | 1.3.3.2.3.2 | **4 player map 2** | 1d | 2003-09-19 08:00 | 2003-09-19 17:00 | 513 | 0d |  | 8h |
| 517 | 1.3.3.2.3.2.1 | Build map | 0.5d | 2003-09-19 08:00 | 2003-09-19 12:00 |  | 0d | Steven Taylor | 4h |
| 518 | 1.3.3.2.3.2.2 | Test map | 0.5d | 2003-09-19 13:00 | 2003-09-19 17:00 | 517 | 0d | Steven Taylor | 4h |
| 519 | 1.3.3.2.3.3 | **4 player map 3** | 1d | 2003-09-22 08:00 | 2003-09-22 17:00 | 516 | 0d |  | 8h |
| 520 | 1.3.3.2.3.3.1 | Build map | 0.5d | 2003-09-22 08:00 | 2003-09-22 12:00 |  | 0d | Steven Taylor | 4h |
| 521 | 1.3.3.2.3.3.2 | Test map | 0.5d | 2003-09-22 13:00 | 2003-09-22 17:00 | 520 | 0d | Steven Taylor | 4h |
| 522 | 1.3.3.2.3.4 | **4 player map 4** | 1d | 2003-09-23 08:00 | 2003-09-23 17:00 | 519 | 0d |  | 8h |
| 523 | 1.3.3.2.3.4.1 | Build map | 0.5d | 2003-09-23 08:00 | 2003-09-23 12:00 |  | 0d | Steven Taylor | 4h |
| 524 | 1.3.3.2.3.4.2 | Test map | 0.5d | 2003-09-23 13:00 | 2003-09-23 17:00 | 523 | 0d | Steven Taylor | 4h |
| 525 | 1.3.3.2.3.5 | **4 player map 5** | 0.5d | 2003-09-24 08:00 | 2003-09-24 12:00 | 522 | 0d |  | 4h |
| 526 | 1.3.3.2.3.5.1 | Build map | 0.25d | 2003-09-24 08:00 | 2003-09-24 10:00 |  | 0d | Steven Taylor | 2h |
| 527 | 1.3.3.2.3.5.2 | Test map | 0.25d | 2003-09-24 10:00 | 2003-09-24 12:00 | 526 | 0d | Steven Taylor | 2h |
| 528 | 1.3.3.2.3.6 | **4 player map 6** | 0.5d | 2003-09-24 13:00 | 2003-09-24 17:00 | 525 | 0d |  | 4h |
| 529 | 1.3.3.2.3.6.1 | Build map | 0.25d | 2003-09-24 13:00 | 2003-09-24 15:00 |  | 0d | Steven Taylor | 2h |
| 530 | 1.3.3.2.3.6.2 | Test map | 0.25d | 2003-09-24 15:00 | 2003-09-24 17:00 | 529 | 0d | Steven Taylor | 2h |
| 531 | 1.3.3.2.3.7 | **4 player map 7** | 0.5d | 2003-09-25 08:00 | 2003-09-25 12:00 | 528 | 0d |  | 4h |
| 532 | 1.3.3.2.3.7.1 | Build map | 0.25d | 2003-09-25 08:00 | 2003-09-25 10:00 |  | 0d | Steven Taylor | 2h |
| 533 | 1.3.3.2.3.7.2 | Test map | 0.25d | 2003-09-25 10:00 | 2003-09-25 12:00 | 532 | 0d | Steven Taylor | 2h |
| 534 | 1.3.3.2.3.8 | **4 player map 8** | 0.5d | 2003-09-25 13:00 | 2003-09-25 17:00 | 531 | 0d |  | 4h |
| 535 | 1.3.3.2.3.8.1 | Build map | 0.25d | 2003-09-25 13:00 | 2003-09-25 15:00 |  | 0d | Steven Taylor | 2h |
| 536 | 1.3.3.2.3.8.2 | Test map | 0.25d | 2003-09-25 15:00 | 2003-09-25 17:00 | 535 | 0d | Steven Taylor | 2h |
| 537 | 1.3.3.2.3.9 | **4 player map 9** | 0.5d | 2003-09-26 08:00 | 2003-09-26 12:00 | 534 | 0d |  | 4h |
| 538 | 1.3.3.2.3.9.1 | Build map | 0.25d | 2003-09-26 08:00 | 2003-09-26 10:00 |  | 0d | Steven Taylor | 2h |
| 539 | 1.3.3.2.3.9.2 | Test map | 0.25d | 2003-09-26 10:00 | 2003-09-26 12:00 | 538 | 0d | Steven Taylor | 2h |

| ID | WBS | Task | Duration | Start | Finish | Predecessors | Total slack | Free slack | Resources | Work |
| --- | --- | --- | --- | --- | --- | --- | --- | --- | --- | --- |
| 540 | 1.3.3.2.3.10 | **4 player map 10** | 0.5d | 2003-09-26 13:00 | 2003-09-26 17:00 | 537 | 0d |  |  | 4h |
| 541 | 1.3.3.2.3.10.1 | Build map | 0.25d | 2003-09-26 13:00 | 2003-09-26 15:00 |  | 0d |  | Steven Taylor | 2h |
| 542 | 1.3.3.2.3.10.2 | Test map | 0.25d | 2003-09-26 15:00 | 2003-09-26 17:00 | 541 | 0d |  | Steven Taylor | 2h |
| 544 | 1.4 | **Full submission Candidate** | 10d | 2003-09-29 08:00 | 2003-10-10 17:00 | 276 | 0d |  |  |  |
| 545 | 1.4.1 | **CODE** | 10d | 2003-09-29 08:00 | 2003-10-10 17:00 |  | 0d |  |  |  |
| 546 | 1.4.1.1 | Fix Bugs | 10d | 2003-09-29 08:00 | 2003-10-10 17:00 |  | 0d |  |  |  |
| 547 | 1.4.2 | **ART** | 10d | 2003-09-29 08:00 | 2003-10-10 17:00 |  | 0d |  |  |  |
| 548 | 1.4.2.1 | Fix Art bugs | 10d | 2003-09-29 08:00 | 2003-10-10 17:00 |  | 0d |  |  |  |
| 549 | 1.4.3 | **DESIGN** | 10d | 2003-09-29 08:00 | 2003-10-10 17:00 |  | 0d |  |  |  |
| 550 | 1.4.3.1 | Fix Map Bugs | 10d | 2003-09-29 08:00 | 2003-10-10 17:00 |  | 0d |  |  |  |
| 552 | 1.5 | **Gold master Candidate** | 10d | 2003-10-13 08:00 | 2003-10-24 17:00 | 544 | 0d |  |  |  |
| 553 | 1.5.1 | goto master | 10d | 2003-10-13 08:00 | 2003-10-24 17:00 |  | 0d |  |  |  |
| 555 | 1.6 | **MUSIC / Sound effects** | 68d | 2003-06-23 08:00 | 2003-09-24 17:00 |  | 13d |  |  | 620h |
| 556 | 1.6.1 | **Speech** | 22d | 2003-06-23 08:00 | 2003-07-22 17:00 |  | 13d | 0d |  | 176h |
| 557 | 1.6.1.1 | **Dialogue Script for campaign map** | 18d | 2003-06-23 08:00 | 2003-07-16 17:00 |  | 13d | 0d |  | 144h |
| 558 | 1.6.1.1.1 | Speech for Donovan Howard | 2d | 2003-06-23 08:00 | 2003-06-24 17:00 |  | 13d | 0d | Script Writer | 16h |
| 559 | 1.6.1.1.2 | Speech for Sue Lee | 2d | 2003-06-25 08:00 | 2003-06-26 17:00 | 558 | 13d | 0d | Script Writer | 16h |
| 560 | 1.6.1.1.3 | Speech for Kurt Rollins | 2d | 2003-06-27 08:00 | 2003-06-30 17:00 | 559 | 13d | 0d | Script Writer | 16h |
| 561 | 1.6.1.1.4 | Speech for Yu Totsami | 2d | 2003-07-01 08:00 | 2003-07-02 17:00 | 560 | 13d | 0d | Script Writer | 16h |
| 562 | 1.6.1.1.5 | Speech For Mr K | 2d | 2003-07-03 08:00 | 2003-07-04 17:00 | 561 | 13d | 0d | Script Writer | 16h |
| 563 | 1.6.1.1.6 | Speech for Charles Nathan Smith | 2d | 2003-07-07 08:00 | 2003-07-08 17:00 | 562 | 13d | 0d | Script Writer | 16h |
| 564 | 1.6.1.1.7 | Speech for Hugh Anderson | 2d | 2003-07-09 08:00 | 2003-07-10 17:00 | 563 | 13d | 0d | Script Writer | 16h |
| 565 | 1.6.1.1.8 | Speech for Lord Excelsior | 2d | 2003-07-11 08:00 | 2003-07-14 17:00 | 564 | 13d | 0d | Script Writer | 16h |
| 566 | 1.6.1.1.9 | Speech for Side Kick | 2d | 2003-07-15 08:00 | 2003-07-16 17:00 | 565 | 13d |  | Script Writer | 16h |

Notes:
- 544: Full submission candidate is a version that is 100% complete. It will only contain Bugs
- 552: Gold master candidate is when the game has been bug-fixed and is deemed ready for release.

| ID | WBS | Task | Duration | Start | Finish | Predecessors | Total slack | Free slack | Resources | Work |
| --- | --- | --- | --- | --- | --- | --- | --- | --- | --- | --- |
| 567 | 1.6.1.2 | **Recording Speech** | 4d | 2003-07-17 08:00 | 2003-07-22 17:00 | 557 | 13d |  |  | 32h |
| 568 | 1.6.1.2.1 | Selecting Voice talent | 3d | 2003-07-17 08:00 | 2003-07-21 17:00 |  | 13d | 0d | Musician | 24h |
| 569 | 1.6.1.2.2 | Record Speech | 1d | 2003-07-22 08:00 | 2003-07-22 17:00 | 568 | 13d |  | Musician | 8h |
| 570 | 1.6.2 | **Menu Sound Effects** | 1d | 2003-07-23 08:00 | 2003-07-23 17:00 | 556 | 13d | 0d |  | 8h |
| 571 | 1.6.2.1 | Accept sound | 0.25d | 2003-07-23 08:00 | 2003-07-23 10:00 |  | 13d | 0d | Musician | 2h |
| 572 | 1.6.2.2 | Decline sound | 0.25d | 2003-07-23 10:00 | 2003-07-23 12:00 | 571 | 13d | 0d | Musician | 2h |
| 573 | 1.6.2.3 | General input | 0.25d | 2003-07-23 13:00 | 2003-07-23 15:00 | 572 | 13d | 0d | Musician | 2h |
| 574 | 1.6.2.4 | new screen | 0.25d | 2003-07-23 15:00 | 2003-07-23 17:00 | 573 | 13d |  | Musician | 2h |
| 575 | 1.6.3 | **Ingame SFX** | 9.5d | 2003-07-24 08:00 | 2003-08-06 12:00 | 570 | 13d | 0d |  | 152h |
| 576 | 1.6.3.1 | **Unit sounds** | 9.5d | 2003-07-24 08:00 | 2003-08-06 12:00 |  | 13d |  | Musician | 152h |
| 577 | 1.6.3.1.1 | Soldier | 0.5d | 2003-07-24 08:00 | 2003-07-24 12:00 |  | 13d | 0d | Musician | 4h |
| 578 | 1.6.3.1.2 | Captain | 0.5d | 2003-07-24 13:00 | 2003-07-24 17:00 | 577 | 13d | 0d | Musician | 4h |
| 579 | 1.6.3.1.3 | Sniper | 0.5d | 2003-07-25 08:00 | 2003-07-25 12:00 | 578 | 13d | 0d | Musician | 4h |
| 580 | 1.6.3.1.4 | motorbike | 0.5d | 2003-07-25 13:00 | 2003-07-25 17:00 | 579 | 13d | 0d | Musician | 4h |
| 581 | 1.6.3.1.5 | Car | 0.5d | 2003-07-28 08:00 | 2003-07-28 12:00 | 580 | 13d | 0d | Musician | 4h |
| 582 | 1.6.3.1.6 | Heavy Car | 0.5d | 2003-07-28 13:00 | 2003-07-28 17:00 | 581 | 13d | 0d | Musician | 4h |
| 583 | 1.6.3.1.7 | Boss car | 0.5d | 2003-07-29 08:00 | 2003-07-29 12:00 | 582 | 13d | 0d | Musician | 4h |
| 584 | 1.6.3.1.8 | Gun truck | 0.5d | 2003-07-29 13:00 | 2003-07-29 17:00 | 583 | 13d | 0d | Musician | 4h |
| 585 | 1.6.3.1.9 | Van | 0.5d | 2003-07-30 08:00 | 2003-07-30 12:00 | 584 | 13d | 0d | Musician | 4h |
| 586 | 1.6.3.1.10 | Lorry | 0.5d | 2003-07-30 13:00 | 2003-07-30 17:00 | 585 | 13d | 0d | Musician | 4h |
| 587 | 1.6.3.1.11 | speedboat | 0.5d | 2003-07-31 08:00 | 2003-07-31 12:00 | 586 | 13d | 0d | Musician | 4h |
| 588 | 1.6.3.1.12 | Cruiser | 0.5d | 2003-07-31 13:00 | 2003-07-31 17:00 | 587 | 13d | 0d | Musician | 4h |
| 589 | 1.6.3.1.13 | Submarine | 0.5d | 2003-08-01 08:00 | 2003-08-01 12:00 | 588 | 13d | 0d | Musician | 4h |
| 590 | 1.6.3.1.14 | Barge | 0.5d | 2003-08-01 13:00 | 2003-08-01 17:00 | 589 | 13d | 0d | Musician | 4h |
| 591 | 1.6.3.1.15 | Bi-Plane | 0.5d | 2003-08-04 08:00 | 2003-08-04 12:00 | 590 | 13d | 0d | Musician | 4h |
| 592 | 1.6.3.1.16 | Fighter | 0.5d | 2003-08-04 13:00 | 2003-08-04 17:00 | 591 | 13d | 0d | Musician | 4h |
| 593 | 1.6.3.1.17 | AA Gun | 0.5d | 2003-08-05 08:00 | 2003-08-05 12:00 | 592 | 13d | 0d | Musician | 4h |
| 594 | 1.6.3.1.18 | Train | 0.5d | 2003-08-05 13:00 | 2003-08-05 17:00 | 593 | 13d | 0d | Musician | 4h |
| 595 | 1.6.3.1.19 | Airship | 0.5d | 2003-08-06 08:00 | 2003-08-06 12:00 | 594 | 13d |  | Musician | 4h |

| ID | WBS | Task | Duration | Start | Finish | Predecessors | Total slack | Free slack | Resources | Work |
| --- | --- | --- | --- | --- | --- | --- | --- | --- | --- | --- |
| 596 | 1.6.4 | **Music** | 35.5d | 2003-08-06 13:00 | 2003-09-24 17:00 | 575 | 13d |  |  | 284h |
| 597 | 1.6.4.1 | **Title music** | 2d | 2003-08-06 13:00 | 2003-08-08 12:00 |  | 13d | 0d |  | 16h |
| 598 | 1.6.4.1.1 | Compose | 1.5d | 2003-08-06 13:00 | 2003-08-07 17:00 |  | 13d | 0d | Musician | 12h |
| 599 | 1.6.4.1.2 | Finalise | 0.5d | 2003-08-08 08:00 | 2003-08-08 12:00 | 598 | 13d |  | Musician | 4h |
| 600 | 1.6.4.2 | **Game Over Lose** | 2d | 2003-08-08 13:00 | 2003-08-12 12:00 | 597 | 13d | 0d |  | 16h |
| 601 | 1.6.4.2.1 | Compose | 1.5d | 2003-08-08 13:00 | 2003-08-11 17:00 |  | 13d | 0d | Musician | 12h |
| 602 | 1.6.4.2.2 | Finalise | 0.5d | 2003-08-12 08:00 | 2003-08-12 12:00 | 601 | 13d |  | Musician | 4h |
| 603 | 1.6.4.3 | **Game Over Win** | 2d | 2003-08-12 13:00 | 2003-08-14 12:00 | 600 | 13d | 0d |  | 16h |
| 604 | 1.6.4.3.1 | Compose | 1.5d | 2003-08-12 13:00 | 2003-08-13 17:00 |  | 13d | 0d | Musician | 12h |
| 605 | 1.6.4.3.2 | Finalise | 0.5d | 2003-08-14 08:00 | 2003-08-14 12:00 | 604 | 13d |  | Musician | 4h |
| 606 | 1.6.4.4 | **Office music (home base)** | 2d | 2003-08-14 13:00 | 2003-08-18 12:00 | 603 | 13d | 0d |  | 16h |
| 607 | 1.6.4.4.1 | Compose | 1.5d | 2003-08-14 13:00 | 2003-08-15 17:00 |  | 13d | 0d | Musician | 12h |
| 608 | 1.6.4.4.2 | Finalise | 0.5d | 2003-08-18 08:00 | 2003-08-18 12:00 | 607 | 13d |  | Musician | 4h |
| 609 | 1.6.4.5 | **Photofit music** | 2d | 2003-08-18 13:00 | 2003-08-20 12:00 | 606 | 13d | 0d |  | 16h |
| 610 | 1.6.4.5.1 | Compose | 1.5d | 2003-08-18 13:00 | 2003-08-19 17:00 |  | 13d | 0d | Musician | 12h |
| 611 | 1.6.4.5.2 | Finalise | 0.5d | 2003-08-20 08:00 | 2003-08-20 12:00 | 610 | 13d |  | Musician | 4h |
| 612 | 1.6.4.6 | **Menu Music** | 2d | 2003-08-20 13:00 | 2003-08-22 12:00 | 609 | 13d | 0d |  | 16h |
| 613 | 1.6.4.6.1 | Compose | 1.5d | 2003-08-20 13:00 | 2003-08-21 17:00 |  | 13d | 0d | Musician | 12h |
| 614 | 1.6.4.6.2 | Finalise | 0.5d | 2003-08-22 08:00 | 2003-08-22 12:00 | 613 | 13d |  | Musician | 4h |
| 615 | 1.6.4.7 | **BattleMap Tunes** | 17.5d | 2003-08-22 13:00 | 2003-09-16 17:00 | 612 | 13d | 0d |  | 140h |
| 616 | 1.6.4.7.1 | **King 1 Battle map music** | 2d | 2003-08-22 13:00 | 2003-08-26 12:00 |  | 13d | 0d |  | 16h |
| 617 | 1.6.4.7.1.1 | Compose | 1.5d | 2003-08-22 13:00 | 2003-08-25 17:00 |  | 13d | 0d | Musician | 12h |
| 618 | 1.6.4.7.1.2 | Finalise | 0.5d | 2003-08-26 08:00 | 2003-08-26 12:00 | 617 | 13d |  | Musician | 4h |
| 619 | 1.6.4.7.2 | **King one battle scene music (variation 1)** | 0.5d | 2003-08-26 13:00 | 2003-08-26 17:00 | 616 | 13d | 0d |  | 4h |
| 620 | 1.6.4.7.2.1 | Compose | 0.25d | 2003-08-26 13:00 | 2003-08-26 15:00 |  | 13d | 0d | Musician | 2h |
| 621 | 1.6.4.7.2.2 | Finalise | 0.25d | 2003-08-26 15:00 | 2003-08-26 17:00 | 620 | 13d |  | Musician | 2h |

| ID | WBS | Task | Duration | Start | Finish | Predecessors | Total slack | Free slack | Resources | Work |
| --- | --- | --- | --- | --- | --- | --- | --- | --- | --- | --- |
| 622 | 1.6.4.7.3 | **King one battle scene music (variation 2)** | 0.5d | 2003-08-27 08:00 | 2003-08-27 12:00 | 619 | 13d | 0d |  | 4h |
| 623 | 1.6.4.7.3.1 | Compose | 0.25d | 2003-08-27 08:00 | 2003-08-27 10:00 |  | 13d | 0d | Musician | 2h |
| 624 | 1.6.4.7.3.2 | Finalise | 0.25d | 2003-08-27 10:00 | 2003-08-27 12:00 | 623 | 13d |  | Musician | 2h |
| 625 | 1.6.4.7.4 | **King one battle scene music (variation 3)** | 0.5d | 2003-08-27 13:00 | 2003-08-27 17:00 | 622 | 13d | 0d |  | 4h |
| 626 | 1.6.4.7.4.1 | Compose | 0.25d | 2003-08-27 13:00 | 2003-08-27 15:00 |  | 13d | 0d | Musician | 2h |
| 627 | 1.6.4.7.4.2 | Finalise | 0.25d | 2003-08-27 15:00 | 2003-08-27 17:00 | 626 | 13d |  | Musician | 2h |
| 628 | 1.6.4.7.5 | **King 2 Battle map music** | 0.5d | 2003-08-28 08:00 | 2003-08-28 12:00 | 625 | 13d | 0d |  | 4h |
| 629 | 1.6.4.7.5.1 | Compose | 0.25d | 2003-08-28 08:00 | 2003-08-28 10:00 |  | 13d | 0d | Musician | 2h |
| 630 | 1.6.4.7.5.2 | Finalise | 0.25d | 2003-08-28 10:00 | 2003-08-28 12:00 | 629 | 13d |  | Musician | 2h |
| 631 | 1.6.4.7.6 | **King 2 battle scene music (variation 1)** | 0.5d | 2003-08-28 13:00 | 2003-08-28 17:00 | 628 | 13d | 0d |  | 4h |
| 632 | 1.6.4.7.6.1 | Compose | 0.25d | 2003-08-28 13:00 | 2003-08-28 15:00 |  | 13d | 0d | Musician | 2h |
| 633 | 1.6.4.7.6.2 | Finalise | 0.25d | 2003-08-28 15:00 | 2003-08-28 17:00 | 632 | 13d |  | Musician | 2h |
| 634 | 1.6.4.7.7 | **King 2 battle scene music (variation 2)** | 0.5d | 2003-08-29 08:00 | 2003-08-29 12:00 | 631 | 13d | 0d |  | 4h |
| 635 | 1.6.4.7.7.1 | Compose | 0.25d | 2003-08-29 08:00 | 2003-08-29 10:00 |  | 13d | 0d | Musician | 2h |
| 636 | 1.6.4.7.7.2 | Finalise | 0.25d | 2003-08-29 10:00 | 2003-08-29 12:00 | 635 | 13d |  | Musician | 2h |
| 637 | 1.6.4.7.8 | **King 2 battle scene music (variation 3)** | 0.5d | 2003-08-29 13:00 | 2003-08-29 17:00 | 634 | 13d | 0d |  | 4h |
| 638 | 1.6.4.7.8.1 | Compose | 0.25d | 2003-08-29 13:00 | 2003-08-29 15:00 |  | 13d | 0d | Musician | 2h |
| 639 | 1.6.4.7.8.2 | Finalise | 0.25d | 2003-08-29 15:00 | 2003-08-29 17:00 | 638 | 13d |  | Musician | 2h |
| 640 | 1.6.4.7.9 | **King 3 Battle map music** | 0.5d | 2003-09-01 08:00 | 2003-09-01 12:00 | 637 | 13d | 0d |  | 4h |
| 641 | 1.6.4.7.9.1 | Compose | 0.25d | 2003-09-01 08:00 | 2003-09-01 10:00 |  | 13d | 0d | Musician | 2h |
| 642 | 1.6.4.7.9.2 | Finalise | 0.25d | 2003-09-01 10:00 | 2003-09-01 12:00 | 641 | 13d |  | Musician | 2h |
| 643 | 1.6.4.7.10 | **King 3 battle scene music (variation 1)** | 0.5d | 2003-09-01 13:00 | 2003-09-01 17:00 | 640 | 13d | 0d |  | 4h |
| 644 | 1.6.4.7.10.1 | Compose | 0.25d | 2003-09-01 13:00 | 2003-09-01 15:00 |  | 13d | 0d | Musician | 2h |
| 645 | 1.6.4.7.10.2 | Finalise | 0.25d | 2003-09-01 15:00 | 2003-09-01 17:00 | 644 | 13d |  | Musician | 2h |

| ID | WBS | Task | Duration | Start | Finish | Predecessors | Total slack | Free slack | Resources | Work |
| --- | --- | --- | --- | --- | --- | --- | --- | --- | --- | --- |
| 646 | 1.6.4.7.11 | **King 3 battle scene music (variation 2)** | 0.5d | 2003-09-02 08:00 | 2003-09-02 12:00 | 643 | 13d | 0d |  | 4h |
| 647 | 1.6.4.7.11.1 | Compose | 0.25d | 2003-09-02 08:00 | 2003-09-02 10:00 |  | 13d | 0d | Musician | 2h |
| 648 | 1.6.4.7.11.2 | Finalise | 0.25d | 2003-09-02 10:00 | 2003-09-02 12:00 | 647 | 13d |  | Musician | 2h |
| 649 | 1.6.4.7.12 | **King 3 battle scene music (variation 3)** | 0.5d | 2003-09-02 13:00 | 2003-09-02 17:00 | 646 | 13d | 0d |  | 4h |
| 650 | 1.6.4.7.12.1 | Compose | 0.25d | 2003-09-02 13:00 | 2003-09-02 15:00 |  | 13d | 0d | Musician | 2h |
| 651 | 1.6.4.7.12.2 | Finalise | 0.25d | 2003-09-02 15:00 | 2003-09-02 17:00 | 650 | 13d |  | Musician | 2h |
| 652 | 1.6.4.7.13 | **King 4 Battle map music** | 0.5d | 2003-09-03 08:00 | 2003-09-03 12:00 | 649 | 13d | 0d |  | 4h |
| 653 | 1.6.4.7.13.1 | Compose | 0.25d | 2003-09-03 08:00 | 2003-09-03 10:00 |  | 13d | 0d | Musician | 2h |
| 654 | 1.6.4.7.13.2 | Finalise | 0.25d | 2003-09-03 10:00 | 2003-09-03 12:00 | 653 | 13d |  | Musician | 2h |
| 655 | 1.6.4.7.14 | **King 4 battle scene music (variation 1)** | 0.5d | 2003-09-03 13:00 | 2003-09-03 17:00 | 652 | 13d | 0d |  | 4h |
| 656 | 1.6.4.7.14.1 | Compose | 0.25d | 2003-09-03 13:00 | 2003-09-03 15:00 |  | 13d | 0d | Musician | 2h |
| 657 | 1.6.4.7.14.2 | Finalise | 0.25d | 2003-09-03 15:00 | 2003-09-03 17:00 | 656 | 13d |  | Musician | 2h |
| 658 | 1.6.4.7.15 | **King 4 battle scene music (variation 2)** | 0.5d | 2003-09-04 08:00 | 2003-09-04 12:00 | 655 | 13d | 0d |  | 4h |
| 659 | 1.6.4.7.15.1 | Compose | 0.25d | 2003-09-04 08:00 | 2003-09-04 10:00 |  | 13d | 0d | Musician | 2h |
| 660 | 1.6.4.7.15.2 | Finalise | 0.25d | 2003-09-04 10:00 | 2003-09-04 12:00 | 659 | 13d |  | Musician | 2h |
| 661 | 1.6.4.7.16 | **King 4 battle scene music (variation 3)** | 0.5d | 2003-09-04 13:00 | 2003-09-04 17:00 | 658 | 13d | 0d |  | 4h |
| 662 | 1.6.4.7.16.1 | Compose | 0.25d | 2003-09-04 13:00 | 2003-09-04 15:00 |  | 13d | 0d | Musician | 2h |
| 663 | 1.6.4.7.16.2 | Finalise | 0.25d | 2003-09-04 15:00 | 2003-09-04 17:00 | 662 | 13d |  | Musician | 2h |
| 664 | 1.6.4.7.17 | **King 5 Battle map music** | 0.5d | 2003-09-05 08:00 | 2003-09-05 12:00 | 661 | 13d | 0d |  | 4h |
| 665 | 1.6.4.7.17.1 | Compose | 0.25d | 2003-09-05 08:00 | 2003-09-05 10:00 |  | 13d | 0d | Musician | 2h |
| 666 | 1.6.4.7.17.2 | Finalise | 0.25d | 2003-09-05 10:00 | 2003-09-05 12:00 | 665 | 13d |  | Musician | 2h |
| 667 | 1.6.4.7.18 | **King 5 battle scene music (variation 1)** | 0.5d | 2003-09-05 13:00 | 2003-09-05 17:00 | 664 | 13d | 0d |  | 4h |
| 668 | 1.6.4.7.18.1 | Compose | 0.25d | 2003-09-05 13:00 | 2003-09-05 15:00 |  | 13d | 0d | Musician | 2h |
| 669 | 1.6.4.7.18.2 | Finalise | 0.25d | 2003-09-05 15:00 | 2003-09-05 17:00 | 668 | 13d |  | Musician | 2h |

| ID | WBS | Task | Duration | Start | Finish | Predecessors | Total slack | Free slack | Resources | Work |
| --- | --- | --- | --- | --- | --- | --- | --- | --- | --- | --- |
| 670 | 1.6.4.7.19 | **King 5 battle scene music (variation 2)** | 0.5d | 2003-09-08 08:00 | 2003-09-08 12:00 | 667 | 13d | 0d |  | 4h |
| 671 | 1.6.4.7.19.1 | Compose | 0.25d | 2003-09-08 08:00 | 2003-09-08 10:00 |  | 13d | 0d | Musician | 2h |
| 672 | 1.6.4.7.19.2 | Finalise | 0.25d | 2003-09-08 10:00 | 2003-09-08 12:00 | 671 | 13d |  | Musician | 2h |
| 673 | 1.6.4.7.20 | **King 5 battle scene music (variation 3)** | 0.5d | 2003-09-08 13:00 | 2003-09-08 17:00 | 670 | 13d | 0d |  | 4h |
| 674 | 1.6.4.7.20.1 | Compose | 0.25d | 2003-09-08 13:00 | 2003-09-08 15:00 |  | 13d | 0d | Musician | 2h |
| 675 | 1.6.4.7.20.2 | Finalise | 0.25d | 2003-09-08 15:00 | 2003-09-08 17:00 | 674 | 13d |  | Musician | 2h |
| 676 | 1.6.4.7.21 | **King 6 Battle map music** | 0.5d | 2003-09-09 08:00 | 2003-09-09 12:00 | 673 | 13d | 0d |  | 4h |
| 677 | 1.6.4.7.21.1 | Compose | 0.25d | 2003-09-09 08:00 | 2003-09-09 10:00 |  | 13d | 0d | Musician | 2h |
| 678 | 1.6.4.7.21.2 | Finalise | 0.25d | 2003-09-09 10:00 | 2003-09-09 12:00 | 677 | 13d |  | Musician | 2h |
| 679 | 1.6.4.7.22 | **King 6 battle scene music (variation 1)** | 0.5d | 2003-09-09 13:00 | 2003-09-09 17:00 | 676 | 13d | 0d |  | 4h |
| 680 | 1.6.4.7.22.1 | Compose | 0.25d | 2003-09-09 13:00 | 2003-09-09 15:00 |  | 13d | 0d | Musician | 2h |
| 681 | 1.6.4.7.22.2 | Finalise | 0.25d | 2003-09-09 15:00 | 2003-09-09 17:00 | 680 | 13d |  | Musician | 2h |
| 682 | 1.6.4.7.23 | **King 6 battle scene music (variation 2)** | 0.5d | 2003-09-10 08:00 | 2003-09-10 12:00 | 679 | 13d | 0d |  | 4h |
| 683 | 1.6.4.7.23.1 | Compose | 0.25d | 2003-09-10 08:00 | 2003-09-10 10:00 |  | 13d | 0d | Musician | 2h |
| 684 | 1.6.4.7.23.2 | Finalise | 0.25d | 2003-09-10 10:00 | 2003-09-10 12:00 | 683 | 13d |  | Musician | 2h |
| 685 | 1.6.4.7.24 | **King 6 battle scene music (variation 3)** | 0.5d | 2003-09-10 13:00 | 2003-09-10 17:00 | 682 | 13d | 0d |  | 4h |
| 686 | 1.6.4.7.24.1 | Compose | 0.25d | 2003-09-10 13:00 | 2003-09-10 15:00 |  | 13d | 0d | Musician | 2h |
| 687 | 1.6.4.7.24.2 | Finalise | 0.25d | 2003-09-10 15:00 | 2003-09-10 17:00 | 686 | 13d |  | Musician | 2h |
| 688 | 1.6.4.7.25 | **King 7 Battle map music** | 0.5d | 2003-09-11 08:00 | 2003-09-11 12:00 | 685 | 13d | 0d |  | 4h |
| 689 | 1.6.4.7.25.1 | Compose | 0.25d | 2003-09-11 08:00 | 2003-09-11 10:00 |  | 13d | 0d | Musician | 2h |
| 690 | 1.6.4.7.25.2 | Finalise | 0.25d | 2003-09-11 10:00 | 2003-09-11 12:00 | 689 | 13d |  | Musician | 2h |
| 691 | 1.6.4.7.26 | **King 7 battle scene music (variation 1)** | 0.5d | 2003-09-11 13:00 | 2003-09-11 17:00 | 688 | 13d | 0d |  | 4h |
| 692 | 1.6.4.7.26.1 | Compose | 0.25d | 2003-09-11 13:00 | 2003-09-11 15:00 |  | 13d | 0d | Musician | 2h |
| 693 | 1.6.4.7.26.2 | Finalise | 0.25d | 2003-09-11 15:00 | 2003-09-11 17:00 | 692 | 13d |  | Musician | 2h |

| ID | WBS | Task | Duration | Start | Finish | Predecessors | Total slack | Free slack | Resources | Work |
| --- | --- | --- | --- | --- | --- | --- | --- | --- | --- | --- |
| 694 | 1.6.4.7.27 | **King 7 battle scene music (variation 2)** | 0.5d | 2003-09-12 08:00 | 2003-09-12 12:00 | 691 | 13d | 0d |  | 4h |
| 695 | 1.6.4.7.27.1 | Compose | 0.25d | 2003-09-12 08:00 | 2003-09-12 10:00 |  | 13d | 0d | Musician | 2h |
| 696 | 1.6.4.7.27.2 | Finalise | 0.25d | 2003-09-12 10:00 | 2003-09-12 12:00 | 695 | 13d |  | Musician | 2h |
| 697 | 1.6.4.7.28 | **King 7 battle scene music (variation 3)** | 0.5d | 2003-09-12 13:00 | 2003-09-12 17:00 | 694 | 13d | 0d |  | 4h |
| 698 | 1.6.4.7.28.1 | Compose | 0.25d | 2003-09-12 13:00 | 2003-09-12 15:00 |  | 13d | 0d | Musician | 2h |
| 699 | 1.6.4.7.28.2 | Finalise | 0.25d | 2003-09-12 15:00 | 2003-09-12 17:00 | 698 | 13d |  | Musician | 2h |
| 700 | 1.6.4.7.29 | **King 8 Battle map music** | 0.5d | 2003-09-15 08:00 | 2003-09-15 12:00 | 697 | 13d | 0d |  | 4h |
| 701 | 1.6.4.7.29.1 | Compose | 0.25d | 2003-09-15 08:00 | 2003-09-15 10:00 |  | 13d | 0d | Musician | 2h |
| 702 | 1.6.4.7.29.2 | Finalise | 0.25d | 2003-09-15 10:00 | 2003-09-15 12:00 | 701 | 13d |  | Musician | 2h |
| 703 | 1.6.4.7.30 | **King 8 battle scene music (variation 1)** | 0.5d | 2003-09-15 13:00 | 2003-09-15 17:00 | 700 | 13d | 0d |  | 4h |
| 704 | 1.6.4.7.30.1 | Compose | 0.25d | 2003-09-15 13:00 | 2003-09-15 15:00 |  | 13d | 0d | Musician | 2h |
| 705 | 1.6.4.7.30.2 | Finalise | 0.25d | 2003-09-15 15:00 | 2003-09-15 17:00 | 704 | 13d |  | Musician | 2h |
| 706 | 1.6.4.7.31 | **King 8 battle scene music (variation 2)** | 0.5d | 2003-09-16 08:00 | 2003-09-16 12:00 | 703 | 13d | 0d |  | 4h |
| 707 | 1.6.4.7.31.1 | Compose | 0.25d | 2003-09-16 08:00 | 2003-09-16 10:00 |  | 13d | 0d | Musician | 2h |
| 708 | 1.6.4.7.31.2 | Finalise | 0.25d | 2003-09-16 10:00 | 2003-09-16 12:00 | 707 | 13d |  | Musician | 2h |
| 709 | 1.6.4.7.32 | **King 8 battle scene music (variation 3)** | 0.5d | 2003-09-16 13:00 | 2003-09-16 17:00 | 706 | 13d |  |  | 4h |
| 710 | 1.6.4.7.32.1 | Compose | 0.25d | 2003-09-16 13:00 | 2003-09-16 15:00 |  | 13d | 0d | Musician | 2h |
| 711 | 1.6.4.7.32.2 | Finalise | 0.25d | 2003-09-16 15:00 | 2003-09-16 17:00 | 710 | 13d |  | Musician | 2h |
| 712 | 1.6.4.8 | **Cut-scene Music** | 6d | 2003-09-17 08:00 | 2003-09-24 17:00 | 615 | 13d |  |  | 48h |
| 713 | 1.6.4.8.1 | **Brooding cutscene Music** | 1.5d | 2003-09-17 08:00 | 2003-09-18 12:00 |  | 13d | 0d |  | 12h |
| 714 | 1.6.4.8.1.1 | Compose | 1d | 2003-09-17 08:00 | 2003-09-17 17:00 |  | 13d | 0d | Musician | 8h |
| 715 | 1.6.4.8.1.2 | Finalise | 0.5d | 2003-09-18 08:00 | 2003-09-18 12:00 | 714 | 13d |  | Musician | 4h |
| 716 | 1.6.4.8.2 | **Happy Cut scene Music** | 1.5d | 2003-09-18 13:00 | 2003-09-19 17:00 | 713 | 13d | 0d |  | 12h |
| 717 | 1.6.4.8.2.1 | Compose | 1d | 2003-09-18 13:00 | 2003-09-19 12:00 |  | 13d | 0d | Musician | 8h |
| 718 | 1.6.4.8.2.2 | Finalise | 0.5d | 2003-09-19 13:00 | 2003-09-19 17:00 | 717 | 13d |  | Musician | 4h |

| ID | WBS | Task | Duration | Start | Finish | Predecessors | Total slack | Free slack | Resources | Work |
| --- | --- | --- | --- | --- | --- | --- | --- | --- | --- | --- |
| 719 | 1.6.4.8.3 | **Action Cut scene music** | 1.5d | 2003-09-22 08:00 | 2003-09-23 12:00 | 716 | 13d | 0d |  | 12h |
| 720 | 1.6.4.8.3.1 | Compose | 1d | 2003-09-22 08:00 | 2003-09-22 17:00 |  | 13d | 0d | Musician | 8h |
| 721 | 1.6.4.8.3.2 | Finalise | 0.5d | 2003-09-23 08:00 | 2003-09-23 12:00 | 720 | 13d |  | Musician | 4h |
| 722 | 1.6.4.8.4 | **General Cutscene Music** | 1.5d | 2003-09-23 13:00 | 2003-09-24 17:00 | 719 | 13d |  |  | 12h |
| 723 | 1.6.4.8.4.1 | Compose | 1d | 2003-09-23 13:00 | 2003-09-24 12:00 |  | 13d | 0d | Musician | 8h |
| 724 | 1.6.4.8.4.2 | Finalise | 0.5d | 2003-09-24 13:00 | 2003-09-24 17:00 | 723 | 13d |  | Musician | 4h |
| 726 | 1.7 | **External (PUBLISHER)** | 1d? | 2003-06-23 08:00 | 2003-06-23 17:00 |  | 80d |  |  |  |
| 727 | 1.7.1 | **Translations** | 1d? | 2003-06-23 08:00 | 2003-06-23 17:00 |  | 80d |  |  |  |
| 728 | 1.7.1.1 | Translate Ingame text / scripts for Spanish | 1d? | 2003-06-23 08:00 | 2003-06-23 17:00 |  | 80d |  |  |  |
| 729 | 1.7.1.2 | Translate Ingame text / Scripts for French | 1d? | 2003-06-23 08:00 | 2003-06-23 17:00 |  | 80d |  |  |  |
| 730 | 1.7.1.3 | Translate Ingame text / Speech for German | 1d? | 2003-06-23 08:00 | 2003-06-23 17:00 |  | 80d |  |  |  |
| 731 | 1.7.1.4 | Translate ingame text / speech for Finnish | 1d? | 2003-06-23 08:00 | 2003-06-23 17:00 |  | 80d |  |  |  |
| 732 | 1.7.2 | **Voice talent** | 1d? | 2003-06-23 08:00 | 2003-06-23 17:00 |  | 80d |  |  |  |
| 733 | 1.7.2.1 | Select voice talent for Spanish | 1d? | 2003-06-23 08:00 | 2003-06-23 17:00 |  | 80d |  |  |  |
| 734 | 1.7.2.2 | Select Voice talent for French | 1d? | 2003-06-23 08:00 | 2003-06-23 17:00 |  | 80d |  |  |  |
| 735 | 1.7.2.3 | Select Voice talent for German | 1d? | 2003-06-23 08:00 | 2003-06-23 17:00 |  | 80d |  |  |  |
| 736 | 1.7.2.4 | Select Voice talent for Finnish | 1d? | 2003-06-23 08:00 | 2003-06-23 17:00 |  | 80d |  |  |  |
| 737 | 1.7.3 | **Recording** | 1d? | 2003-06-23 08:00 | 2003-06-23 17:00 |  | 80d |  |  |  |
| 738 | 1.7.3.1 | Record and cut speech for Spanish | 1d? | 2003-06-23 08:00 | 2003-06-23 17:00 |  | 80d |  |  |  |
| 739 | 1.7.3.2 | Record and cut speech for French | 1d? | 2003-06-23 08:00 | 2003-06-23 17:00 |  | 80d |  |  |  |
| 740 | 1.7.3.3 | Record and cut speech for German | 1d? | 2003-06-23 08:00 | 2003-06-23 17:00 |  | 80d |  |  |  |
| 741 | 1.7.3.4 | Record and cut speech for Finnish | 1d? | 2003-06-23 08:00 | 2003-06-23 17:00 |  | 80d |  |  |  |
| 743 | 1.8 | **TEST** | 1d | 2003-06-23 08:00 | 2003-06-23 17:00 |  | 80d |  |  |  |
| 744 | 1.8.1 | To be added later | 1d | 2003-06-23 08:00 | 2003-06-23 17:00 |  | 80d |  |  |  |

Notes:
- 732: This is only able to happen if we can fit the amount of speech on to the MMC.
- 743: Test schedule to be filled in later when the test plan is approved and internal and external testing has been co-ordinated and scheduled.
